# Plan pruebas

Schedule from MS Project, 2006-03-22 to 2006-05-10, A marks actual dates.
gm

## Calendars

- Estándar: Mon-Fri 09:00-13:00, 15:00-19:00; Sat-Sun off. Exceptions (off unless hours are given): 2006-04-13 to 2006-04-14, 2006-04-19, 2006-05-01.

## Resources

| Resource |
| --- |
| Rec. Comercial |
| Req. Operaciones |
| Rec. Manten |
| Rea. Admin |
| Usuario |
| Req. Operaciones 2 |
| Req. Operaciones2 |

## Schedule

| ID | WBS | Task | Type | Duration | Start | Finish | Predecessors | Complete | Remaining | Total slack | Free slack | Constraint | Resources | Work | Actual work |
| --- | --- | --- | --- | --- | --- | --- | --- | --- | --- | --- | --- | --- | --- | --- | --- |
| 1 | 1 | **Pruebas Funcionales** |  | 32d? | 2006-03-22 A | 2006-05-10 |  | 54% | 14.72d? | 0d |  |  |  | 381.33h | 216.2h |
| 2 | 1.1 | Acceso |  | 2d | 2006-03-22 A | 2006-03-23 A |  | 100% |  |  |  | start no earlier than 2006-03-22 | Usuario | 16h | 16h |
| 3 | 1.2 | **Comercial** |  | 22d? | 2006-03-22 A | 2006-04-26 |  | 47% | 11.59d? | 10d |  |  |  | 56h | 30.4h |
| 4 | 1.2.1 | Grupo/Subgrupos/Servicios |  | 1d | 2006-03-22 A | 2006-03-22 A |  | 100% |  |  |  | start no earlier than 2006-03-22 | Rec. Comercial | 8h | 8h |
| 5 | 1.2.2 | Tarifas |  | 1d | 2006-03-23 A | 2006-03-23 | 4 | 40% | 0.6d | 27.7d | 0d |  | Rec. Comercial | 8h | 3.2h |
| 6 | 1.2.3 | Precios |  | 1d | 2006-03-24 A | 2006-03-24 | 5 | 30% | 0.7d | 27.4d | 0d |  | Rec. Comercial | 8h | 2.4h |
| 7 | 1.2.4 | Períodos |  | 1d | 2006-03-27 A | 2006-03-27 | 6 | 20% | 0.8d | 27.2d | 0d |  |  |  |  |
| 8 | 1.2.5 | CAPS |  | 1d | 2006-03-28 A | 2006-03-28 | 7 | 20% | 0.8d | 27d |  |  |  |  |  |
| 9 | 1.2.6 | Sesion Trabajo 1 | milestone | 0d | 2006-03-29 A | 2006-03-29 A | 8 | 100% |  |  |  | start no earlier than 2006-03-29 |  |  |  |
| 10 | 1.2.7 | Clientes |  | 1d | 2006-03-30 A | 2006-03-30 | 9 | 50% | 0.5d | 18d | 0d | start no earlier than 2006-03-30 |  |  |  |
| 11 | 1.2.8 | Convenios |  | 1d | 2006-03-31 | 2006-03-31 | 10 |  |  | 18d | 4d |  |  |  |  |
| 12 | 1.2.9 | Sesion Trabajo 2 | milestone | 0d | 2006-04-07 A | 2006-04-07 A | 11 | 100% |  |  |  | start no earlier than 2006-04-07 |  |  |  |
| 13 | 1.2.10 | Cotizaciones |  | 2d | 2006-04-03 A | 2006-04-04 |  | 90% | 0.2d | 18.7d | 0d | start no earlier than 2006-04-03 |  |  |  |
| 14 | 1.2.11 | Reservaciones |  | 2d | 2006-04-05 A | 2006-04-06 | 13 | 30% | 1.4d | 11.6d | 0d |  |  |  |  |
| 15 | 1.2.12 | Consultas |  | 2d | 2006-04-07 A | 2006-04-10 | 14 | 80% | 0.4d | 10d | 0d | start no earlier than 2006-04-07 | Rec. Comercial | 16h | 12.8h |
| 16 | 1.2.13 | Sesión Trabajo 3 | milestone | 0d | 2006-04-18 A | 2006-04-18 A |  | 100% |  |  |  | start no earlier than 2006-04-18 |  |  |  |
| 17 | 1.2.14 | Reportes |  | 1d? | 2006-04-11 A | 2006-04-11 | 15 | 25% | 0.75d? | 16.25d | 0d |  | Rec. Comercial | 8h | 2h |
| 18 | 1.2.15 | Alarmas |  | 1d? | 2006-04-12 A | 2006-04-12 | 17 | 25% | 0.75d? | 16d |  |  | Rec. Comercial | 8h | 2h |
| 19 | 1.2.16 | Sesión trabajo 4 | milestone | 0d | 2006-04-26 | 2006-04-26 |  |  |  | 4d |  | start no earlier than 2006-04-26 |  |  |  |
| 20 | 1.3 | **Operaciones** |  | 26d? | 2006-03-22 A | 2006-05-03 |  | 47% | 13.9d? | 6d |  |  |  | 245.33h | 115.4h |
| 21 | 1.3.1 | Estación |  | 0.5d | 2006-03-22 A | 2006-03-22 A |  | 100% |  |  |  | start no earlier than 2006-03-22 | Req. Operaciones | 4h | 4h |
| 22 | 1.3.2 | Impuestos |  | 0.5d | 2006-03-22 A | 2006-03-22 A |  | 100% |  |  |  | start no earlier than 2006-03-22 | Req. Operaciones | 4h | 4h |
| 23 | 1.3.3 | Parámetros |  | 0.5d | 2006-03-23 A | 2006-03-23 A |  | 100% |  |  |  | start no earlier than 2006-03-23 | Req. Operaciones | 4h | 4h |
| 24 | 1.3.4 | Preingreso |  | 0.5d | 2006-03-24 A | 2006-03-24 A |  | 100% |  |  |  | start no earlier than 2006-03-24 | Req. Operaciones | 4h | 4h |
| 25 | 1.3.5 | Sesion Trabajo 1 | milestone | 0d | 2006-03-29 A | 2006-03-29 A | 24 | 100% |  |  |  | start no earlier than 2006-03-29 |  |  |  |
| 26 | 1.3.6 | Ingreso |  | 0.5d | 2006-03-29 A | 2006-03-29 A | 25 | 100% |  |  |  |  | Req. Operaciones | 4h | 4h |
| 27 | 1.3.7 | Solic Traslado |  | 0.5d | 2006-03-27 A | 2006-03-27 A |  | 100% |  |  |  | start no earlier than 2006-03-27 | Req. Operaciones | 4h | 4h |
| 28 | 1.3.8 | Lista Negra |  | 1d? | 2006-03-27 A | 2006-03-27 |  | 25% | 0.75d? | 28d |  | start no earlier than 2006-03-27 | Req. Operaciones 2 | 8h | 2h |
| 29 | 1.3.9 | Trasaldo |  | 1d | 2006-03-28 A | 2006-03-28 A |  | 100% |  |  |  | start no earlier than 2006-03-28 | Req. Operaciones | 8h | 8h |
| 30 | 1.3.10 | Uso Vehículo |  | 1d? | 2006-03-29 A | 2006-03-29 A |  | 100% |  |  |  | start no earlier than 2006-03-29 | Req. Operaciones | 8h | 8h |
| 31 | 1.3.11 | Siniestro |  | 1d? | 2006-03-30 A | 2006-03-30 |  | 90% | 0.1d? | 25d |  | start no earlier than 2006-03-30 | Req. Operaciones | 8h | 7.2h |
| 32 | 1.3.12 | Punto Chequeo |  | 1d? | 2006-03-31 A | 2006-03-31 A |  | 100% |  |  |  | finish no earlier than 2006-03-31 | Req. Operaciones | 8h | 8h |
| 33 | 1.3.13 | Venta |  | 1d? | 2006-04-03 A | 2006-04-03 |  | 25% | 0.75d? | 22.75d | 7d | start no earlier than 2006-04-03 | Req. Operaciones | 8h | 2h |
| 34 | 1.3.14 | Apertura Contrato |  | 2d | 2006-03-29 A | 2006-03-30 |  | 30% | 1.4d | 13.9d | 0d | start no earlier than 2006-03-29 | Req. Operaciones 2 | 16h | 4.8h |
| 35 | 1.3.15 | Cierre Contrato |  | 2d | 2006-03-31 A | 2006-04-03 | 34 | 30% | 1.4d | 13.3d | 8d | start no earlier than 2006-03-31 | Req. Operaciones 2 | 16h | 4.8h |
| 36 | 1.3.16 | Extensión |  | 1d | 2006-04-07 A | 2006-04-07 A | 35 | 100% |  |  |  | start no earlier than 2006-04-07 | Req. Operaciones 2 | 8h | 8h |
| 37 | 1.3.17 | Sesion Trabajo 2 | milestone | 0d | 2006-04-07 A | 2006-04-07 A | 36 | 100% |  |  |  | start no earlier than 2006-04-07 |  |  |  |
| 38 | 1.3.18 | Cambio Unidad |  | 2d | 2006-04-11 A | 2006-04-12 | 37 | 25% | 1.5d | 16d |  | start no earlier than 2006-04-11 | Req. Operaciones 2 | 16h | 4h |
| 39 | 1.3.19 | Audtoría Contrato |  | 0.5d | 2006-04-17 A | 2006-04-17 | 33 | 50% | 0.25d | 15.5d |  | start no earlier than 2006-04-14 | Req. Operaciones | 4h | 2h |
| 40 | 1.3.20 | Anulación Contratos |  | 0.5d | 2006-04-17 A | 2006-04-17 A | 39 | 100% |  |  |  | start no earlier than 2006-04-17 | Req. Operaciones | 4h | 4h |
| 41 | 1.3.21 | Facturación |  | 2d | 2006-04-18 A | 2006-04-20 | 35 | 50% | 1d | 6.5d | 0d | start no earlier than 2006-04-18 | Req. Operaciones 2 | 16h | 8h |
| 42 | 1.3.22 | Sesión Trabajo 3 | milestone | 0d | 2006-04-20 | 2006-04-20 | 41 |  |  | 6.5d | 0d | start no earlier than 2006-04-18 |  |  |  |
| 43 | 1.3.23 | Anulación Facturas |  | 0.5d | 2006-04-21 | 2006-04-21 | 42 |  |  | 12.5d |  | start no earlier than 2006-04-21 | Req. Operaciones | 4h |  |
| 44 | 1.3.24 | Facturación Adelantada |  | 2d | 2006-04-21 | 2006-04-24 | 41 |  |  | 4.5d | 0d | start no earlier than 2006-04-21 | Req. Operaciones 2 | 16h |  |
| 45 | 1.3.25 | Consultas |  | 1d? | 2006-04-24 A | 2006-04-24 |  | 80% | 0.2d? | 11d |  | start no earlier than 2006-04-24 | Req. Operaciones | 8h | 6.4h |
| 46 | 1.3.26 | Comisiones operadores-freelance |  | 0.5d? | 2006-04-25 A | 2006-04-25 |  | 30% | 0.35d? | 10.5d |  | start no earlier than 2006-04-25 | Req. Operaciones | 4h | 1.2h |
| 47 | 1.3.27 | Costos Traslados |  | 0.5d | 2006-04-25 A | 2006-04-25 A | 44 | 100% |  |  |  | start no earlier than 2006-04-25 | Req. Operaciones 2 | 4h | 4h |
| 48 | 1.3.28 | Empleados por Ciudad |  | 0.5d | 2006-04-26 A | 2006-04-26 |  | 25% | 0.38d | 9.5d |  | start no earlier than 2006-04-26 | Req. Operaciones | 4h | 1h |
| 49 | 1.3.29 | Reportes |  | 3d? | 2006-04-25 A | 2006-04-27 | 40 | 25% | 2.25d? | 8d |  | finish no earlier than 2006-04-27 | Req. Operaciones 2 [50%]; Req. Operaciones [50%] | 22.67h | 6h |
| 50 | 1.3.30 | Sesión trabajo 4 | milestone | 0d | 2006-04-26 | 2006-04-26 |  |  |  | 4d |  | start no earlier than 2006-04-26 |  |  |  |
| 51 | 1.3.31 | Alarmas |  | 1d | 2006-04-28 A | 2006-04-28 |  | 25% | 0.75d | 7d |  | start no earlier than 2006-04-28 | Req. Operaciones | 8h | 2h |
| 52 | 1.3.32 | Estadísticas |  | 3d | 2006-04-27 | 2006-05-02 |  |  |  | 6d |  | start no earlier than 2006-04-27 | Req. Operaciones [50%]; Req. Operaciones 2 [50%] | 22.67h |  |
| 53 | 1.3.33 | Sesión Trabajo 5 | milestone | 0d | 2006-05-03 | 2006-05-03 |  |  |  | 6d |  | start no earlier than 2006-05-03 |  |  |  |

| ID | WBS | Task | Type | Duration | Start | Finish | Predecessors | Complete | Remaining | Total slack | Free slack | Constraint | Resources | Work | Actual work |
| --- | --- | --- | --- | --- | --- | --- | --- | --- | --- | --- | --- | --- | --- | --- | --- |
| 54 | 1.4 | **Mantenimiento** |  | 7d? | 2006-03-27 A | 2006-04-04 |  | 97% | 0.2d? | 22d |  |  |  | 56h | 54.4h |
| 55 | 1.4.1 | Ordenes de Trabajo |  | 3d | 2006-03-27 A | 2006-03-29 A |  | 100% |  |  |  | finish no earlier than 2006-03-29 | Rec. Manten | 24h | 24h |
| 56 | 1.4.2 | Solicitud Productos |  | 1d? | 2006-03-30 A | 2006-03-30 A | 55 | 100% |  |  |  |  | Rec. Manten | 8h | 8h |
| 57 | 1.4.3 | Aprobación pedidos |  | 1d? | 2006-03-31 A | 2006-03-31 A | 56 | 100% |  |  |  |  | Rec. Manten | 8h | 8h |
| 58 | 1.4.4 | Consultas |  | 1d | 2006-04-03 A | 2006-04-03 | 57 | 80% | 0.2d | 16d | 0d |  | Rec. Manten | 8h | 6.4h |
| 59 | 1.4.5 | Alarmas |  | 1d? | 2006-04-04 A | 2006-04-04 A | 58 | 100% |  |  |  |  | Rec. Manten | 8h | 8h |
| 60 | 1.4.6 | Sesion Trabajo 1 | milestone | 0d | 2006-03-29 | 2006-03-29 |  |  |  | 21d |  | start no earlier than 2006-03-29 |  |  |  |
| 61 | 1.5 | **Administrativo** |  | 2d? | 2006-04-27 A | 2006-04-28 |  | 50% | 1d? | 7d |  |  |  | 8h |  |
| 62 | 1.5.1 | Reportes |  | 1d? | 2006-04-27 | 2006-04-27 |  |  |  | 1d | 0d | start no earlier than 2006-04-27 | Rea. Admin | 8h |  |
| 63 | 1.5.2 | Sesion Trabajo 1 | milestone | 0d | 2006-04-27 | 2006-04-27 | 62 |  |  | 1d | 0d | start no earlier than 2006-03-29 |  |  |  |
| 64 | 1.5.3 | Alarmas |  | 1d? | 2006-04-28 A | 2006-04-28 A | 63 | 100% |  |  |  |  |  |  |  |
| 65 | 1.6 | **Ajsutes sesión 5** |  | 1d? | 2006-05-10 | 2006-05-10 |  |  |  | 0d |  |  |  |  |  |
| 66 | 1.6.1 | Sesion Trabajo 6 |  | 1d? | 2006-05-10 | 2006-05-10 |  |  |  | 0d |  | start no earlier than 2006-05-10 |  |  |  |
