# Proyecto CRM - Corporacion Union

Schedule from MS Project, 2006-08-07 to 2006-11-30.

## Calendars

- Estándar: Mon-Fri 08:00-12:00, 13:00-17:00; Sat-Sun off.

## Resources

| Resource |
| --- |
| LR |
| BC-Merc |
| GS |
| BC-Sist |
| Aron |
| FA |
| AG |
| RC |
| Lore |
| BC-CG |

## Schedule

| ID | WBS | Task | Type | Duration | Start | Finish | Predecessors | Total slack | Free slack | Constraint | Resources | Work |
| --- | --- | --- | --- | --- | --- | --- | --- | --- | --- | --- | --- | --- |
| 1 | 1 | **Proyecto Intranet Banco Caroní** |  | 84d | 2006-08-07 | 2006-11-30 |  | 0d |  |  |  | 1903h |
| 2 | 1.1 | Reunión de Arranque |  | 1d | 2006-08-07 | 2006-08-07 |  | 83d |  | start no earlier than 2006-08-07 | LR; GS; BC-Merc; BC-Sist [50%] | 28h |
| 3 | 1.2 | Análsis y preparación material para definición requerimientos |  | 1d | 2006-08-08 | 2006-08-08 | 2 | 82d |  |  | LR [50%]; BC-Merc [50%] | 8h |
| 4 | 1.3 | **Especificación de Requerimientos** |  | 30d | 2006-08-09 | 2006-09-19 |  | 52d |  |  |  | 162h |
| 5 | 1.3.1 | **Levantamiento de Información** |  | 7d | 2006-08-09 | 2006-08-17 |  | 75d |  |  |  | 40h |
| 6 | 1.3.1.1 | Sesión de Trabajo # 1 - Puerto Ordáz |  | 1d | 2006-08-09 | 2006-08-09 |  | 81d |  | start no earlier than 2006-08-09 | LR; BC-Merc; BC-Sist | 24h |
| 7 | 1.3.1.2 | Sesión de Trabajo # 2 - CCS |  | 1d | 2006-08-17 | 2006-08-17 |  | 75d |  | start no earlier than 2006-08-17 | LR [50%]; FA [50%]; GS [50%]; BC-Merc [50%] | 16h |
| 8 | 1.3.2 | Elaboración del Informe Especificación de Req. |  | 2d | 2006-08-18 | 2006-08-21 |  | 73d |  | start no earlier than 2006-08-18 | LR [50%] | 8h |
| 9 | 1.3.3 | Entrega al Equipo de Proyecto BC para su revisión | milestone | 0d | 2006-08-23 | 2006-08-23 |  | 51d | 0d | start no earlier than 2006-08-23 | GS |  |
| 10 | 1.3.4 | Revisión por parte del Equipo de Proyecto BC |  | 10d | 2006-08-23 | 2006-09-05 | 9 | 51d | 0d |  | BC-Merc [50%]; BC-Sist [50%]; BC-CG [25%] | 100h |
| 11 | 1.3.5 | Recepción de ajustes recomendados al Informe | milestone | 0d | 2006-09-05 | 2006-09-05 | 10 | 51d | 0d |  | LR |  |
| 12 | 1.3.6 | Ajustes al Informe Especificación de Requerimientos |  | 3d | 2006-09-06 | 2006-09-08 | 11 | 51d | 0d |  | LR [33.3%] | 8h |
| 13 | 1.3.7 | Entrega de Especificación de Req. para aprobación | milestone | 0d | 2006-09-08 | 2006-09-08 | 12 | 51d | 4d |  | LR |  |
| 14 | 1.3.8 | Aprobación del Informe Especificación de Requerimientos |  | 3d | 2006-09-15 | 2006-09-19 | 13 | 47d | 0d | start no earlier than 2006-09-15 | BC-Merc [50%]; BC-Sist [50%]; BC-CG [25%] | 6h |
| 15 | 1.3.9 | Informe Especificación de Requerimientos Aprobado | milestone | 0d | 2006-09-19 | 2006-09-19 | 14 | 47d | 0d |  |  |  |
| 16 | 1.4 | **Preparación de la información base para implantación** |  | 17d | 2006-08-23 | 2006-09-15 |  | 55d |  |  |  | 54h |
| 17 | 1.4.1 | Estructura de Documentos |  | 5d | 2006-08-23 | 2006-08-29 |  | 67d |  | start no earlier than 2006-08-23 | BC-Sist [25%] | 10h |
| 18 | 1.4.2 | Enlace a las aplicaciones C/S |  | 5d | 2006-08-23 | 2006-08-29 |  | 67d |  | start no earlier than 2006-08-23 | BC-Sist [25%] | 10h |
| 19 | 1.4.3 | Enlace a aplicaciones WEB |  | 5d | 2006-08-28 | 2006-09-01 |  | 64d |  | start no earlier than 2006-08-28 | BC-Sist [25%] | 10h |
| 20 | 1.4.4 | Usuarios y perfiles |  | 2d | 2006-09-11 | 2006-09-12 |  | 57d |  | start no earlier than 2006-09-11 | LR; BC-Merc [25%]; BC-Sist [25%] | 24h |
| 21 | 1.4.5 | Entrega de información para implantación a GWT | milestone | 0d | 2006-09-15 | 2006-09-15 |  | 55d |  | start no earlier than 2006-09-15 |  |  |
| 22 | 1.5 | **Diseño Gráfico Intranet** |  | 33d | 2006-08-28 | 2006-10-11 |  | 0d |  |  |  | 221h |
| 23 | 1.5.1 | Manejo de la relación con empresa publicidad |  | 30d | 2006-08-28 | 2006-10-06 |  | 39d |  | start no earlier than 2006-08-28 | BC-Merc [25%] | 60h |
| 24 | 1.5.2 | Definición, control y entrega |  | 30d | 2006-08-28 | 2006-10-06 |  | 0d |  | start no earlier than 2006-08-28 | FA [30%]; BC-Merc [25%] | 132h |
| 25 | 1.5.3 | Validación del trabajo resultante con el Comité Guia |  | 3d | 2006-10-09 | 2006-10-11 | 24 | 0d |  |  | LR [10.4%]; FA [10.4%]; BC-Merc [50%]; BC-CG [50%] | 29h |
| 26 | 1.5.4 | Diseño Intranet definido y aprobado | milestone | 0d | 2006-10-11 | 2006-10-11 | 25 | 0d |  |  |  |  |

| ID | WBS | Task | Type | Duration | Start | Finish | Predecessors | Total slack | Free slack | Constraint | Resources | Work |
| --- | --- | --- | --- | --- | --- | --- | --- | --- | --- | --- | --- | --- |
| 27 | 1.6 | **Configuración y Desarrollo** |  | 62d | 2006-08-18 | 2006-11-13 |  | 13d |  |  |  | 778h |
| 28 | 1.6.1 | Creación estructura WiB3 para la Intranet |  | 2d | 2006-08-18 | 2006-08-21 |  | 73d |  | start no earlier than 2006-08-18 | Aron [25%] | 4h |
| 29 | 1.6.2 | Creación de aplicaciones en N2C |  | 2d | 2006-08-18 | 2006-08-21 |  | 73d |  | start no earlier than 2006-08-18 | Aron [25%] | 4h |
| 30 | 1.6.3 | **Configuración WiB3** |  | 53d | 2006-08-21 | 2006-11-01 |  | 21d |  |  |  | 120h |
| 31 | 1.6.3.1 | Diseño Preliminar |  | 10d | 2006-08-21 | 2006-09-01 |  | 62d | 0d | start no earlier than 2006-08-21 | FA [50%] | 40h |
| 32 | 1.6.3.2 | Preparación y presentación prototipo |  | 2d | 2006-09-04 | 2006-09-05 | 31 | 62d |  |  | FA [50%] | 8h |
| 33 | 1.6.3.3 | Incorporación diseño elaborado por empresa publicidad |  | 10d | 2006-10-12 | 2006-10-25 | 26 | 0d |  |  | FA [50%] | 40h |
| 34 | 1.6.3.4 | Presentación y aprobación por parte del Comite Guía |  | 3d | 2006-10-26 | 2006-10-30 | 33 | 0d |  |  | BC-Merc [50%]; BC-CG [50%] | 24h |
| 35 | 1.6.3.5 | Ajustes sobre recomendaciones Comité Guía |  | 2d | 2006-10-31 | 2006-11-01 | 34 | 21d |  |  | FA [50%] | 8h |
| 36 | 1.6.4 | **Configuración Nuevas Aplicaciones** |  | 30d | 2006-08-21 | 2006-09-29 |  | 42d |  |  |  | 584h |
| 37 | 1.6.4.1 | Mensajes Corporativos y Macroperfiles |  | 14d | 2006-09-11 | 2006-09-28 |  | 45d |  | start no earlier than 2006-09-11 | Lore [71.4%] | 80h |
| 38 | 1.6.4.2 | Avisos Clasificados |  | 10d | 2006-08-21 | 2006-09-01 |  | 44d | 0d | start no earlier than 2006-08-21 | AG; Lore [5%] | 84h |
| 39 | 1.6.4.3 | Gestión de Documentos |  | 10d | 2006-09-04 | 2006-09-15 | 38 | 44d | 0d | start no earlier than 2006-01-31 | AG; Lore [5%] | 84h |
| 40 | 1.6.4.4 | Administración de Caricaturas |  | 10d | 2006-08-21 | 2006-09-01 |  | 43d | 0d | start no earlier than 2006-08-21 | RC; Lore [5%] | 84h |
| 41 | 1.6.4.5 | Administración de BroadCast (Ventanas Emergentes) |  | 10d | 2006-09-04 | 2006-09-15 | 40 | 43d | 0d | start no earlier than 2006-02-13 | RC; Lore [5%] | 84h |
| 42 | 1.6.4.6 | Guía Telefónica |  | 10d | 2006-09-18 | 2006-09-29 | 41 | 42d | 0d | start no earlier than 2006-02-10 | RC; Lore [5%] | 84h |
| 43 | 1.6.4.7 | Reservación de Salas |  | 10d | 2006-09-18 | 2006-09-29 | 39 | 44d |  |  | AG; Lore [5%] | 84h |
| 44 | 1.6.5 | **Configuración WiB3** |  | 10d | 2006-10-31 | 2006-11-13 |  | 0d |  |  |  | 66h |
| 45 | 1.6.5.1 | Definición páginas (Tipo Contenido, Aplicación) |  | 3d | 2006-10-31 | 2006-11-02 | 34 | 0d |  | start no earlier than 2006-09-18 | FA [50%]; Lore [50%] | 24h |
| 46 | 1.6.5.2 | Definición de aplicaciones N2C |  | 3d | 2006-11-03 | 2006-11-07 | 45 | 0d |  | start no earlier than 2006-02-16 | FA [25%]; Lore [50%] | 18h |
| 47 | 1.6.5.3 | Integración con aplicaciones BC |  | 4d | 2006-11-08 | 2006-11-13 | 46 | 0d |  | start no earlier than 2006-02-21 | Lore [50%]; LR [25%] | 24h |
| 48 | 1.7 | Nuevo diseño de la intranet configurado | milestone | 0d | 2006-11-13 | 2006-11-13 | 47 | 13d |  |  |  |  |
| 49 | 1.8 | Nuevas funcionalidades en la Intranet incorporadas | milestone | 0d | 2006-11-13 | 2006-11-13 | 47 | 0d |  |  |  |  |
| 50 | 1.9 | **Plan de Pruebas** |  | 5d | 2006-09-20 | 2006-09-26 |  | 47d |  |  |  | 24h |
| 51 | 1.9.1 | Elaboración Plan de Pruebas |  | 2d | 2006-09-20 | 2006-09-21 | 15 | 47d | 0d | start no earlier than 2006-02-15 | LR [25%] | 4h |
| 52 | 1.9.2 | Revisión Plan de Pruebas con Equipo de Trabajo |  | 2d | 2006-09-22 | 2006-09-25 | 51 | 47d | 0d |  | LR [50%]; BC-Merc [25%]; BC-Sist [25%] | 16h |
| 53 | 1.9.3 | Ajustes recomendados al Plan de Pruebas |  | 1d | 2006-09-26 | 2006-09-26 | 52 | 47d | 0d |  | LR [50%] | 4h |
| 54 | 1.10 | Plan de Pruebas elaborado y revisado | milestone | 0d | 2006-09-26 | 2006-09-26 | 53 | 47d |  |  |  |  |

| ID | WBS | Task | Type | Duration | Start | Finish | Predecessors | Total slack | Free slack | Constraint | Resources | Work |
| --- | --- | --- | --- | --- | --- | --- | --- | --- | --- | --- | --- | --- |
| 55 | 1.11 | **Pruebas de Certificación** |  | 9d | 2006-11-14 | 2006-11-24 |  | 0d |  |  |  | 82h |
| 56 | 1.11.1 | Preparación para las pruebas en ambiente de desarrollo |  | 1d | 2006-11-14 | 2006-11-14 | 49 | 0d |  | start no earlier than 2005-06-20 | LR [25%] | 2h |
| 57 | 1.11.2 | Realización de Pruebas de Funcionalidad |  | 5d | 2006-11-15 | 2006-11-21 | 56 | 0d |  | start no earlier than 2005-07-12 | LR [20%]; Lore [20%]; BC-Merc [50%]; BC-Sist [50%] | 56h |
| 58 | 1.11.3 | Realización de Ajustes recomendados |  | 3d | 2006-11-22 | 2006-11-24 | 57 | 0d |  |  | FA [25%]; AG [25%]; RC [25%]; Lore [25%] | 24h |
| 59 | 1.12 | Pruebas Certificadas | milestone | 0d | 2006-11-24 | 2006-11-24 | 58 | 0d |  |  |  |  |
| 60 | 1.13 | **Documentación** |  | 42d | 2006-10-02 | 2006-11-28 |  | 2d |  |  |  | 52h |
| 61 | 1.13.1 | Consolidación y estructuración de documentos técnicos |  | 2d | 2006-10-02 | 2006-10-03 | 42 | 42d |  |  | LR | 16h |
| 62 | 1.13.2 | Ajustes a la documentación |  | 2d | 2006-11-27 | 2006-11-28 | 59 | 2d |  |  | LR [25%]; AG [25%]; RC [25%]; Lore [25%] | 16h |
| 63 | 1.13.3 | Técnica WIB |  | 5d | 2006-11-06 | 2006-11-10 |  | 14d |  | start no earlier than 2006-11-06 | FA [50%] | 20h |
| 64 | 1.14 | **Migración de versiones N2C y WiB en Banco Caroní** |  | 22d | 2006-10-16 | 2006-11-14 |  | 12d |  |  |  | 132h |
| 65 | 1.14.1 | **Ambiente de Desarrollo** |  | 15d | 2006-10-16 | 2006-11-03 |  | 12d |  |  |  | 90h |
| 66 | 1.14.1.1 | Planificación y Configuración Infraestructura Técnica |  | 10d | 2006-10-16 | 2006-10-27 |  | 12d | 0d | start no earlier than 2006-10-16 | Aron [50%]; BC-Sist [25%] | 60h |
| 67 | 1.14.1.2 | Pruebas y ajustes aplicaciones existentes |  | 5d | 2006-10-30 | 2006-11-03 | 66 | 12d | 0d |  | LR [25%]; Lore [50%] | 30h |
| 68 | 1.14.2 | Ambiente de Desarrollo con nuevas versiones | milestone | 0d | 2006-11-03 | 2006-11-03 | 67 | 19d |  |  |  |  |
| 69 | 1.14.3 | **Ambiente de Producción** |  | 7d | 2006-11-06 | 2006-11-14 |  | 12d |  |  |  | 42h |
| 70 | 1.14.3.1 | Planificación y Configuración Infraestructura Técnica |  | 5d | 2006-11-06 | 2006-11-10 | 67 | 12d | 0d |  | Aron [50%]; BC-Sist [25%] | 30h |
| 71 | 1.14.3.2 | Pruebas y ajustes aplicaciones existentes |  | 2d | 2006-11-13 | 2006-11-14 | 70 | 12d | 0d |  | LR [25%]; Lore [50%] | 12h |
| 72 | 1.14.4 | Ambiente de Producción con nuevas versiones | milestone | 0d | 2006-11-14 | 2006-11-14 | 71 | 12d |  |  |  |  |
| 73 | 1.15 | **Adiestramiento** |  | 4d | 2006-11-20 | 2006-11-23 |  | 5d |  |  |  | 64h |
| 74 | 1.15.1 | WiB3 |  | 2d | 2006-11-20 | 2006-11-21 |  | 5d | 0d | start no earlier than 2006-11-20 | FA; LR | 32h |
| 75 | 1.15.2 | Aplicaciones de Administración Contenido |  | 2d | 2006-11-22 | 2006-11-23 | 74 | 5d |  |  | LR; Lore | 32h |
| 76 | 1.16 | **Puesta en Producción** |  | 3d | 2006-11-27 | 2006-11-29 |  | 0d |  |  |  | 32h |
| 77 | 1.16.1 | Migración de aplicaciones |  | 2d | 2006-11-27 | 2006-11-28 | 59 | 0d |  |  | Aron [50%] | 8h |
| 78 | 1.16.2 | Pruebas integrales |  | 1d | 2006-11-29 | 2006-11-29 | 77 | 0d |  |  | LR; Lore; BC-Sist | 24h |
| 79 | 1.17 | Manejo del Cambio |  | 50d | 2006-09-18 | 2006-11-24 |  | 4d |  | start no earlier than 2006-09-18 | BC-Merc [5%] | 20h |

Notes:
- 75: Incluye aplicaciones nuevas: / Adm. Caricaturas, Guía Telefónica, Ventanas Emergentes, Documentos, Avisos Clasificados y Mensajes Corporativos

| ID | WBS | Task | Duration | Start | Finish | Predecessors | Total slack | Constraint | Resources | Work |
| --- | --- | --- | --- | --- | --- | --- | --- | --- | --- | --- |
| 80 | 1.18 | **Gerencia de Proyecto** | 77d | 2006-08-14 | 2006-11-28 |  | 2d |  |  | 198h |
| 81 | 1.18.1 | Planificación | 25d | 2006-08-14 | 2006-09-15 |  | 54d | start no earlier than 2006-08-14 | LR [15%] | 30h |
| 82 | 1.18.2 | Control y Seguimiento | 70d | 2006-08-23 | 2006-11-28 |  | 2d | start no earlier than 2006-08-23 | LR [30%] | 168h |
| 83 | 1.19 | **Cierre** | 4d | 2006-11-27 | 2006-11-30 |  | 0d |  |  | 48h |
| 84 | 1.19.1 | Preparación Presentación Cierre de Proyecto | 4d | 2006-11-27 | 2006-11-30 |  | 0d | start no earlier than 2006-11-27 | LR [25%] | 8h |
| 85 | 1.19.2 | Reunión Cierre de Proyecto | 1d | 2006-11-30 | 2006-11-30 | 76 | 0d | start no earlier than 2006-03-31 | LR; GS; BC-Merc; BC-Sist; BC-CG | 40h |
