# Cronograma Fase 1

Schedule from MS Project, 2008-03-31 to 2008-04-08.
gwt

## Calendars

- Standard: Mon-Fri 08:00-12:00, 13:00-17:00; Sat-Sun off.

## Resources

| Resource |
| --- |
| Mcolmenarez |
| Flor |
| Falvarez |
| Programador |
| Operaciones |

## Schedule

| ID | WBS | Task | Type | Duration | Start | Finish | Predecessors | Total slack | Resources | Work |
| --- | --- | --- | --- | --- | --- | --- | --- | --- | --- | --- |
| 1 | 1 | **Web Site Bremmer Motors** |  | 6.64d | 2008-03-31 08:00 | 2008-04-08 14:07 |  | 0d |  | 57h |
| 2 | 1.1 | **Diseño** |  | 0.75d | 2008-03-31 08:00 | 2008-03-31 15:00 |  | 0d |  | 6h |
| 3 | 1.1.1 | Propuesta Gráfica |  | 0.75d | 2008-03-31 08:00 | 2008-03-31 15:00 |  | 0d | Falvarez | 6h |
| 4 | 1.1.2 | Aprobación Propuesta Gráfica | milestone | 0d | 2008-03-31 15:00 | 2008-03-31 15:00 | 3 | 0d |  |  |
| 5 | 1.2 | **Desarrollo** |  | 4.14d | 2008-03-31 15:00 | 2008-04-04 16:07 |  | 0d |  | 36h |
| 6 | 1.2.1 | **Formularios** |  | 1.89d | 2008-03-31 15:00 | 2008-04-02 14:07 | 4 | 0d |  | 18h |
| 7 | 1.2.1.1 | Cotizacioes |  | 0.63d | 2008-03-31 15:00 | 2008-04-01 11:02 | 4 | 0d | Flor [99.2%] | 5h |
| 8 | 1.2.1.2 | Accesorios |  | 0.63d | 2008-04-01 11:02 | 2008-04-02 08:04 | 7 | 0d | Flor [99.2%] | 5h |
| 9 | 1.2.1.3 | Contactenos |  | 0.63d | 2008-04-02 08:04 | 2008-04-02 14:07 | 8 | 0d |  | 5h |
| 10 | 1.2.1.4 | Citas al Publico |  | 0.38d | 2008-03-31 15:00 | 2008-04-01 09:02 |  | 5.51d |  | 3h |
| 11 | 1.2.2 | Banners |  | 0.75d | 2008-04-02 14:07 | 2008-04-03 11:07 | 9 | 0d | Flor | 6h |
| 12 | 1.2.3 | Googles Analyitics |  | 1.5d | 2008-04-03 11:07 | 2008-04-04 16:07 | 11 | 0d | Flor | 12h |
| 13 | 1.3 | Pruebas |  | 0.25d | 2008-04-04 16:07 | 2008-04-07 09:07 | 12 | 0d |  | 2h |
| 14 | 1.4 | Documentación |  | 0.5d | 2008-04-07 09:07 | 2008-04-07 14:07 | 13 | 0d |  | 4h |
| 15 | 1.5 | **Operacionalización y puesta en servicio** |  | 1d | 2008-04-07 14:07 | 2008-04-08 14:07 |  | 0d |  | 5h |
| 16 | 1.5.1 | Operacionalización |  | 0.5d | 2008-04-07 14:07 | 2008-04-08 09:07 | 14 | 0d | Operaciones [75%] | 3h |
| 17 | 1.5.2 | Entrenamiento |  | 0.5d | 2008-04-08 09:07 | 2008-04-08 14:07 | 16 | 0d | Mcolmenarez [50%] | 2h |
| 18 | 1.6 | Gerencia Proyecto |  | 0.5d | 2008-03-31 08:00 | 2008-03-31 12:00 |  | 6.14d | Mcolmenarez | 4h |
