# Nuevo Pendientes-Factibles

Schedule from MS Project, 2008-07-01 to 2008-12-11, A marks actual dates.
KATET

## Calendars

- Estándar: Mon-Fri 09:00-13:00, 15:00-19:00; Sat-Sun off.

## Resources

| Resource |
| --- |
| GP |
| OP |
| DS |
| DS2 |

## Schedule

| ID | WBS | Task | Type | Duration | Start | Finish | Predecessors | Complete | Remaining | Total slack | Free slack | Constraint | Resources | Work | Actual work |
| --- | --- | --- | --- | --- | --- | --- | --- | --- | --- | --- | --- | --- | --- | --- | --- |
| 1 | 1 | **Cines Unidos** |  | 116.62d? | 2008-07-01 A | 2008-12-11 |  | 61% | 45.04d? | 0d |  |  |  | 767h | 355.68h |
| 2 | 1.1 | **Fase III - Integración** |  | 100.33d? | 2008-07-01 A | 2008-11-19 |  | 68% | 32.03d? | 0.29d | 0d |  |  | 661h | 316.2h |
| 3 | 1.1.1 | Actividades Previas al 23 Sept |  | 59.25d? | 2008-07-01 A | 2008-09-22 A |  | 100% |  |  |  | finish no earlier than 2008-09-22 | DS [50%] | 237h | 237h |
| 4 | 1.1.2 | Análisis de integraciones (ambiente local y directorios virtuales) |  | 4d? | 2008-09-23 A | 2008-09-26 A |  | 100% |  |  |  | start no earlier than 2008-09-23 | DS [50%] | 16h | 16h |
| 5 | 1.1.3 | Migración a N2C 5.1 (en pippin y en tecnologiainternet) |  | 1.82d? | 2008-10-01 A | 2008-10-02 A |  | 100% |  |  |  | start no earlier than 2008-10-01 | OP [50%]; DS [10%] | 8h | 8h |
| 6 | 1.1.4 | Ajustes de CRM por cambio de versión y por ambiente Windows |  | 5.56d? | 2008-10-06 A | 2008-10-13 | 11 | 40% | 3.33d? | 0.29d | 0d |  | DS [90%] | 40h | 16h |
| 7 | 1.1.5 | **Cambios Módulo Contacto** |  | 12.56d? | 2008-09-29 A | 2008-10-15 A |  | 100% |  |  |  |  |  | 24h | 24h |
| 8 | 1.1.5.1 | Datos nuevos en Formulario |  | 1d? | 2008-09-29 A | 2008-09-29 A | 4 | 100% |  |  |  |  | DS [50%] | 4h | 4h |
| 9 | 1.1.5.2 | Datos nuevos en detalle de contacto y en email |  | 1d? | 2008-09-30 A | 2008-09-30 A | 8 | 100% |  |  |  |  | DS [50%] | 4h | 4h |
| 10 | 1.1.5.3 | Cambio en valores de Lista de Categorías y asociación grupos contactos |  | 2d? | 2008-10-01 A | 2008-10-02 A | 9 | 100% |  |  |  |  | DS [50%] | 8h | 8h |
| 11 | 1.1.5.4 | Pruebas y ajustes |  | 1d? | 2008-10-03 A | 2008-10-03 A | 10 | 100% |  |  |  |  | DS [50%] | 4h | 4h |
| 12 | 1.1.5.5 | Pruebas certificación por parte de Cines Unidos |  | 4d | 2008-10-06 A | 2008-10-09 A | 11 | 100% |  |  |  |  |  |  |  |
| 13 | 1.1.5.6 | Puesta en producción |  | 1d? | 2008-10-13 A | 2008-10-14 A | 6 | 100% |  |  |  |  | DS [50%] | 4h | 4h |
| 14 | 1.1.5.7 | Módulo de Contacto en producción |  | 1d? | 2008-10-14 A | 2008-10-15 A | 13 | 100% |  |  |  |  |  |  |  |
| 15 | 1.1.6 | **Integración Sitio Web** |  | 3.33d? | 2008-10-06 A | 2008-10-09 |  | 63% | 1.22d? | 23.42d | 0d |  |  | 24h | 15.2h |
| 16 | 1.1.6.1 | Ajustes |  | 2.22d? | 2008-10-06 A | 2008-10-08 | 11 | 95% | 0.11d? | 23.42d | 0d |  | DS2 [90%] | 16h | 15.2h |
| 17 | 1.1.6.2 | Implantación y pruebas en Pippin |  | 1.11d? | 2008-10-08 | 2008-10-09 | 16 |  |  | 23.42d |  |  | DS2 [90%] | 8h |  |
| 18 | 1.1.7 | **Integración Tiendas Cines Unidos** |  | 5.62d? | 2008-10-09 | 2008-10-16 |  |  |  | 23.42d |  |  |  | 36h |  |
| 19 | 1.1.7.1 | Ajustes |  | 3.75d? | 2008-10-09 | 2008-10-15 | 15 |  |  | 23.42d | 0d |  | DS2 [80%] | 24h |  |
| 20 | 1.1.7.2 | Implantación y pruebas en Pippin |  | 1.88d? | 2008-10-15 | 2008-10-16 | 19 |  |  | 23.42d |  |  | DS2 [80%] | 12h |  |
| 21 | 1.1.8 | **Integración Transacciones** |  | 5.56d? | 2008-10-14 | 2008-10-22 |  |  |  | 0.29d | 0d |  |  | 40h |  |
| 22 | 1.1.8.1 | Desarrollo |  | 4.44d? | 2008-10-14 | 2008-10-20 | 13 |  |  | 0.29d | 0d |  | DS [90%] | 32h |  |
| 23 | 1.1.8.2 | Implantación y Pruebas en Pippin |  | 1.11d? | 2008-10-21 | 2008-10-22 | 22 |  |  | 0.29d |  |  | DS [90%] | 8h |  |
| 24 | 1.1.9 | Documentación Diccionario de Datos Vista |  | 1d? | 2008-10-10 | 2008-10-10 |  |  |  | 7.4d | 7.11d | start no earlier than 2008-10-10 |  |  |  |
| 25 | 1.1.10 | Integración Vista (Transacciones de Sitio Web) |  | 6.94d? | 2008-10-22 | 2008-10-31 | 24, 21 |  |  | 0.29d | 0d |  | DS [90%]; DS2 [90%] | 100h |  |
| 26 | 1.1.11 | Documentación Diccionario de Datos CC Vista |  | 1d? | 2008-10-17 | 2008-10-17 |  |  |  | 9.35d | 9.06d | start no earlier than 2008-10-17 |  |  |  |
| 27 | 1.1.12 | Integración CC-Vista (Clientes) |  | 8.93d? | 2008-10-31 | 2008-11-12 | 26, 25 |  |  | 0.29d | 0d |  | DS [90%]; DS2 [70%] | 100h |  |
| 28 | 1.1.13 | Documento Guia de Configuración de Integraciones |  | 2.22d? | 2008-11-12 | 2008-11-17 | 27 |  |  | 0.29d | 0d |  | DS [90%] | 16h |  |
| 29 | 1.1.14 | Pruebas internas y Ajustes |  | 1.88d | 2008-11-17 | 2008-11-19 | 28 |  |  | 0.29d |  |  | GP [10%]; DS [90%]; DS2 [80%] | 20h |  |
| 30 | 1.2 | Migración de Programas de Integración a Pippin (dir desarrollo) |  | 2d | 2008-11-19 | 2008-11-21 | 2 |  |  | 0.29d | 0d |  | DS [50%]; OP [25%] | 8h |  |
| 31 | 1.3 | Preparación Pruebas de Certificación |  | 3d | 2008-11-21 | 2008-11-26 | 30 |  |  | 0.29d | 0d |  | DS [50%] | 12h |  |
| 32 | 1.4 | Apoyo en Pruebas de Certificación |  | 5d | 2008-11-26 | 2008-12-03 | 31 |  |  | 6.29d |  |  | DS [10%] | 4h |  |
| 33 | 1.5 | Pruebas de Certificación por parte de Cines Unidos |  | 5d | 2008-11-26 | 2008-12-03 | 31 |  |  | 0.29d | 0d |  |  |  |  |
| 34 | 1.6 | Ajustes |  | 4d? | 2008-12-03 | 2008-12-09 | 33 |  |  | 0.29d | 0d |  | DS [50%] | 16h |  |
| 35 | 1.7 | Verificación de Ajustes por parte de Cines Unidos |  | 1d | 2008-12-09 | 2008-12-10 | 34 |  |  | 0.29d | 0d |  |  |  |  |
| 36 | 1.8 | Pase a Producción de Integraciones |  | 1d | 2008-12-10 | 2008-12-11 | 35 |  |  | 0.29d | 0d |  | OP [50%]; DS [50%] | 8h |  |
| 37 | 1.9 | CRM completo en Producción | milestone | 0d | 2008-12-11 | 2008-12-11 | 36 |  |  | 0.29d |  |  |  |  |  |
| 38 | 1.10 | Gerencia de Proyectos |  | 42.88d | 2008-09-23 A | 2008-12-11 |  | 73% | 11.58d | 0d |  | start no earlier than 2008-09-23 | GP [20%] | 58h | 39.48h |
