# Cronograma Sistema Gestion

Schedule from MS Project, 2008-09-01 to 2008-12-19.

## Calendars

- Estándar: Mon-Fri 09:00-13:00, 15:00-19:00; Sat-Sun off.

## Resources

| Resource |
| --- |
| Yenny Colmenarez |
| Gustavo Ledezma |
| Jetzelis Heredia |
| Marbella Colmenarez |

## Schedule

| ID | WBS | Task | Duration | Start | Finish | Predecessors | Total slack | Free slack | Resources | Work |
| --- | --- | --- | --- | --- | --- | --- | --- | --- | --- | --- |
| 1 | 1 | **Sistema de Gestion Kitchen Fair** | 79.92d? | 2008-09-01 | 2008-12-19 |  | 0d |  |  | 1522h |
| 2 | 1.1 | **Kick-Off del Proyecto** | 2d? | 2008-09-01 | 2008-09-02 |  | 58.92d |  |  | 4h |
| 3 | 1.1.1 | Elaboración de Presentación del Kick-Off | 1d? | 2008-09-01 | 2008-09-01 |  | 50d | 0d |  | 2h |
| 4 | 1.1.2 | Reunion de Kick-Off | 1d? | 2008-09-02 | 2008-09-02 | 3 | 64d |  |  | 2h |
| 5 | 1.2 | **Análisis y Levant. Información** | 5d? | 2008-09-02 | 2008-09-08 |  | 58.92d |  |  | 384h |
| 6 | 1.2.1 | Visitas al cliente para levantar información | 1d? | 2008-09-02 | 2008-09-02 | 3 | 50d | 0d |  | 112h |
| 7 | 1.2.2 | Llamadas para levantar Información | 1d? | 2008-09-03 | 2008-09-03 | 6 | 50d | 0d |  | 24h |
| 8 | 1.2.3 | Analisis de Informacion | 1d? | 2008-09-04 | 2008-09-04 | 7 | 50d | 0d |  | 120h |
| 9 | 1.2.4 | Diseño Interfaz | 1d? | 2008-09-05 | 2008-09-05 | 8 | 61d |  |  | 8h |
| 10 | 1.2.5 | Diseño Estructura de Datos | 1d? | 2008-09-05 | 2008-09-05 | 8 | 50d | 0d |  | 40h |
| 11 | 1.2.6 | Elaboración de informe de requerimientos | 1d? | 2008-09-08 | 2008-09-08 | 10 | 50d | 0d |  | 80h |
| 12 | 1.3 | **Desarrollo** | 76.92d? | 2008-09-01 | 2008-12-16 |  | 0d |  |  | 832h |
| 13 | 1.3.1 | **Módulo de clientes** | 12d? | 2008-09-09 | 2008-09-24 |  | 58.92d |  |  | 50h |
| 14 | 1.3.1.1 | Tablas Módulo Clientes | 0.5d? | 2008-09-09 | 2008-09-09 | 11 | 70.42d |  | Yenny Colmenarez [50%] | 2h |
| 15 | 1.3.1.2 | Programas pre-post-formula | 2d? | 2008-09-09 | 2008-09-10 | 11 | 58.92d | 0d | Yenny Colmenarez [50%] | 8h |
| 16 | 1.3.1.3 | Estado de cuenta del cliente | 2.5d? | 2008-09-11 | 2008-09-15 | 15 | 58.92d | 0d | Yenny Colmenarez [50%] | 10h |
| 17 | 1.3.1.4 | Busquedas clientes | 1d? | 2008-09-15 | 2008-09-16 | 16 | 58.92d | 0d | Yenny Colmenarez [50%] | 4h |
| 18 | 1.3.1.5 | Reportes Clientes | 4d? | 2008-09-16 | 2008-09-22 | 17 | 58.92d | 0d | Yenny Colmenarez [50%] | 16h |
| 19 | 1.3.1.6 | Vistas extendidas Clientes | 2.5d? | 2008-09-22 | 2008-09-24 | 18 | 58.92d |  | Yenny Colmenarez [50%] | 10h |
| 20 | 1.3.2 | **Módulo de Consultores** | 11.75d? | 2008-09-09 | 2008-09-24 |  | 59.17d |  |  | 102h |
| 21 | 1.3.2.1 | Tablas Módulo Consultores | 0.25d? | 2008-09-09 | 2008-09-09 | 11 | 59.17d | 0d | Gustavo Ledezma | 2h |
| 22 | 1.3.2.2 | Programas pre-post-formula | 1d? | 2008-09-09 | 2008-09-10 | 21 | 59.17d | 0d | Gustavo Ledezma | 8h |
| 23 | 1.3.2.3 | Cupones | 0.5d? | 2008-09-10 | 2008-09-10 | 22 | 69.17d |  | Gustavo Ledezma | 4h |
| 24 | 1.3.2.4 | Kits | 0.5d? | 2008-09-10 | 2008-09-10 | 22 | 59.17d | 0d | Gustavo Ledezma | 4h |
| 25 | 1.3.2.5 | Premios | 0.5d? | 2008-09-10 | 2008-09-11 | 24 | 68.67d |  | Gustavo Ledezma | 4h |
| 26 | 1.3.2.6 | Pines | 0.5d? | 2008-09-10 | 2008-09-11 | 24 | 59.17d | 0d | Gustavo Ledezma | 4h |
| 27 | 1.3.2.7 | Ascensos y descensos del consultor | 2d? | 2008-09-11 | 2008-09-15 | 26 | 59.17d | 0d | Gustavo Ledezma | 16h |
| 28 | 1.3.2.8 | Estado de cuenta del consultor | 2d? | 2008-09-15 | 2008-09-17 | 27 | 59.17d | 0d | Gustavo Ledezma | 16h |
| 29 | 1.3.2.9 | Busquedas consultores | 0.5d? | 2008-09-17 | 2008-09-17 | 28 | 59.17d | 0d | Gustavo Ledezma | 4h |
| 30 | 1.3.2.10 | Reportes Consultores | 3d? | 2008-09-17 | 2008-09-22 | 29 | 59.17d | 0d | Gustavo Ledezma | 24h |
| 31 | 1.3.2.11 | Vistas extendidas Consultores | 1d? | 2008-09-22 | 2008-09-23 | 30 | 59.17d | 0d | Gustavo Ledezma | 8h |
| 32 | 1.3.2.12 | Cálculo de efectividad del consultor | 1d? | 2008-09-23 | 2008-09-24 | 31 | 59.17d |  | Gustavo Ledezma | 8h |

| ID | WBS | Task | Duration | Start | Finish | Predecessors | Total slack | Free slack | Constraint | Resources | Work |
| --- | --- | --- | --- | --- | --- | --- | --- | --- | --- | --- | --- |
| 33 | 1.3.3 | **Módulo de Ventas** | 16.75d? | 2008-10-13 | 2008-11-04 |  | 0d |  |  |  | 134h |
| 34 | 1.3.3.1 | Tablas Módulo Ventas | 0.25d? | 2008-10-13 | 2008-10-13 |  | 0d |  | start no earlier than 2008-10-13 | Gustavo Ledezma | 2h |
| 35 | 1.3.3.2 | Programas pre-post-formula | 3d? | 2008-10-13 | 2008-10-16 | 34 | 0d |  |  | Gustavo Ledezma | 24h |
| 36 | 1.3.3.3 | Ingreso de pedidos | 3d? | 2008-10-16 | 2008-10-21 | 35 | 0d |  |  | Gustavo Ledezma | 24h |
| 37 | 1.3.3.4 | Validaciones de pedidos | 1d? | 2008-10-21 | 2008-10-22 | 36 | 0d |  |  | Gustavo Ledezma | 8h |
| 38 | 1.3.3.5 | Promociones | 1d? | 2008-10-22 | 2008-10-23 | 37 | 0d |  |  | Gustavo Ledezma | 8h |
| 39 | 1.3.3.6 | Reverso de pedidos, comisiones y puntos | 3d? | 2008-10-23 | 2008-10-28 | 38 | 0d |  |  | Gustavo Ledezma | 24h |
| 40 | 1.3.3.7 | Devoluciones (Garantías) | 2d? | 2008-10-28 | 2008-10-30 | 39 | 0d |  |  | Gustavo Ledezma | 16h |
| 41 | 1.3.3.8 | Busquedas pedidos | 0.5d? | 2008-10-30 | 2008-10-30 | 40 | 0d |  |  | Gustavo Ledezma | 4h |
| 42 | 1.3.3.9 | Reportes Ventas | 2d? | 2008-10-30 | 2008-11-03 | 41 | 0d |  |  | Gustavo Ledezma | 16h |
| 43 | 1.3.3.10 | Vistas extendidas Ventas | 1d? | 2008-11-03 | 2008-11-04 | 42 | 0d |  |  | Gustavo Ledezma | 8h |
| 44 | 1.3.4 | **Módulo de Análisis de Crédito** | 16.5d? | 2008-11-04 | 2008-11-27 |  | 0d |  |  |  | 132h |
| 45 | 1.3.4.1 | Pantalla Analisis de crédito | 1d? | 2008-11-04 | 2008-11-05 | 43 | 0d |  |  | Gustavo Ledezma | 8h |
| 46 | 1.3.4.2 | Cambio de Status pedidos | 1d? | 2008-11-05 | 2008-11-06 | 45 | 0d |  |  | Gustavo Ledezma | 8h |
| 47 | 1.3.4.3 | Domiciliación de Pagos | 2d? | 2008-11-06 | 2008-11-10 | 46 | 0d |  |  | Gustavo Ledezma | 16h |
| 48 | 1.3.4.4 | Calculo de comisiones, puntos, acumulado ventas | 2d? | 2008-11-10 | 2008-11-12 | 47 | 0d |  |  | Gustavo Ledezma | 16h |
| 49 | 1.3.4.5 | Captación de interacciones con bancos | 1d? | 2008-11-12 | 2008-11-13 | 48 | 0d |  |  | Gustavo Ledezma | 8h |
| 50 | 1.3.4.6 | Preparación de datos en formato de c/ banco | 2d? | 2008-11-13 | 2008-11-17 | 49 | 0d |  |  | Gustavo Ledezma | 16h |
| 51 | 1.3.4.7 | Notificaciones pedidos pendientes | 0.5d? | 2008-11-17 | 2008-11-18 | 50 | 0d |  |  | Gustavo Ledezma | 4h |
| 52 | 1.3.4.8 | Reportes de Analisis de Credito | 3d? | 2008-11-18 | 2008-11-21 | 51 | 0d |  |  | Gustavo Ledezma | 24h |
| 53 | 1.3.4.9 | Vistas Extendidas Analisis de Credito | 1d? | 2008-11-21 | 2008-11-24 | 52 | 0d |  |  | Gustavo Ledezma | 8h |
| 54 | 1.3.4.10 | Estadisticas de Analisis de Credito | 3d? | 2008-11-24 | 2008-11-27 | 53 | 0d |  |  | Gustavo Ledezma | 24h |
| 55 | 1.3.5 | **Módulo de Cobranzas** | 36d? | 2008-10-13 | 2008-12-01 |  | 10.92d |  |  |  | 144h |
| 56 | 1.3.5.1 | Tablas Módulo Cobranzas | 0.5d? | 2008-10-13 | 2008-10-13 |  | 10.92d | 0d | start no earlier than 2008-10-13 | Yenny Colmenarez [50%] | 2h |
| 57 | 1.3.5.2 | Programas pre-post-formula | 2d? | 2008-10-13 | 2008-10-15 | 56 | 10.92d | 0d |  | Yenny Colmenarez [50%] | 8h |
| 58 | 1.3.5.3 | Registro de pagos | 4d? | 2008-10-15 | 2008-10-21 | 57 | 10.92d | 0d |  | Yenny Colmenarez [50%] | 16h |
| 59 | 1.3.5.4 | Reverso de pagos | 4d? | 2008-10-21 | 2008-10-27 | 58 | 10.92d | 0d |  | Yenny Colmenarez [50%] | 16h |
| 60 | 1.3.5.5 | Recalculo de cuotas pronto pago | 2d? | 2008-10-27 | 2008-10-29 | 59 | 10.92d | 0d |  | Yenny Colmenarez [50%] | 8h |
| 61 | 1.3.5.6 | Refinanciamiento | 2d? | 2008-10-29 | 2008-10-31 | 60 | 10.92d | 0d |  | Yenny Colmenarez [50%] | 8h |
| 62 | 1.3.5.7 | Intereses de mora | 2d? | 2008-10-31 | 2008-11-04 | 61 | 10.92d | 0d |  | Yenny Colmenarez [50%] | 8h |
| 63 | 1.3.5.8 | Notas de debito y credito | 2d? | 2008-11-04 | 2008-11-06 | 62 | 10.92d | 0d |  | Yenny Colmenarez [50%] | 8h |
| 64 | 1.3.5.9 | Reportes de llamadas diarias | 1d? | 2008-11-06 | 2008-11-07 | 63 | 10.92d | 0d |  | Yenny Colmenarez [50%] | 4h |
| 65 | 1.3.5.10 | Captación del resultado de la llamada | 1d? | 2008-11-07 | 2008-11-10 | 64 | 10.92d | 0d |  | Yenny Colmenarez [50%] | 4h |
| 66 | 1.3.5.11 | Preparación de Transacciones para c/ banco | 6d? | 2008-11-10 | 2008-11-18 | 65 | 10.92d | 0d |  | Yenny Colmenarez [50%] | 24h |
| 67 | 1.3.5.12 | Busquedas Cobranzas | 1d? | 2008-11-18 | 2008-11-19 | 66 | 10.92d | 0d |  | Yenny Colmenarez [50%] | 4h |
| 68 | 1.3.5.13 | Reportes Cobranzas | 6d? | 2008-11-19 | 2008-11-27 | 67 | 10.92d | 0d |  | Yenny Colmenarez [50%] | 24h |
| 69 | 1.3.5.14 | Vistas extendidas Cobranzas | 2d? | 2008-11-27 | 2008-12-01 | 68 | 10.92d | 0d |  | Yenny Colmenarez [50%] | 8h |
| 70 | 1.3.5.15 | Pantalla p/Analistas de cobranzas | 0.5d? | 2008-12-01 | 2008-12-01 | 69 | 10.92d |  |  | Yenny Colmenarez [50%] | 2h |

| ID | WBS | Task | Duration | Start | Finish | Predecessors | Total slack | Free slack | Constraint | Resources | Work |
| --- | --- | --- | --- | --- | --- | --- | --- | --- | --- | --- | --- |
| 71 | 1.3.6 | **Módulo de Despacho** | 76.92d? | 2008-09-01 | 2008-12-16 |  | 0d |  |  |  | 156h |
| 72 | 1.3.6.1 | Tablas Módulo Despacho | 1d? | 2008-11-27 | 2008-11-28 | 54 | 0d |  |  | Gustavo Ledezma | 8h |
| 73 | 1.3.6.2 | Programas pre-post-formula | 2d? | 2008-11-28 | 2008-12-02 | 72 | 0d |  |  | Gustavo Ledezma | 16h |
| 74 | 1.3.6.3 | Carga y descarga de inventario | 0.67d? | 2008-12-02 | 2008-12-02 | 73 | 0d |  |  | Gustavo Ledezma; Yenny Colmenarez [50%] | 8h |
| 75 | 1.3.6.4 | Ingreso de productos | 0.67d? | 2008-12-02 | 2008-12-03 | 74 | 0d |  |  | Gustavo Ledezma; Yenny Colmenarez [50%] | 8h |
| 76 | 1.3.6.5 | Traslado de productos entre depositos | 0.67d? | 2008-12-03 | 2008-12-04 | 75 | 0d |  |  | Gustavo Ledezma; Yenny Colmenarez [50%] | 8h |
| 77 | 1.3.6.6 | Devolucion de productos | 0.33d? | 2008-12-04 | 2008-12-04 | 76 | 0d |  |  | Gustavo Ledezma; Yenny Colmenarez [50%] | 4h |
| 78 | 1.3.6.7 | Ingreso de despacho | 2d? | 2008-12-04 | 2008-12-08 | 77 | 0d |  |  | Gustavo Ledezma; Yenny Colmenarez [50%] | 24h |
| 79 | 1.3.6.8 | Reverso de despacho | 2d? | 2008-12-08 | 2008-12-10 | 78 | 0d |  |  | Gustavo Ledezma; Yenny Colmenarez [50%] | 24h |
| 80 | 1.3.6.9 | Comprobantes de despacho | 1.33d? | 2008-12-10 | 2008-12-11 | 79 | 0d |  |  | Gustavo Ledezma; Yenny Colmenarez [50%] | 16h |
| 81 | 1.3.6.10 | Busquedas Despacho | 0.33d? | 2008-12-11 | 2008-12-12 | 80 | 0d |  |  | Gustavo Ledezma; Yenny Colmenarez [50%] | 4h |
| 82 | 1.3.6.11 | Reportes Despacho | 2d? | 2008-12-12 | 2008-12-16 | 81 | 0d |  |  | Gustavo Ledezma; Yenny Colmenarez [50%] | 24h |
| 83 | 1.3.6.12 | Vistas extendidas Despacho | 0.67d? | 2008-12-16 | 2008-12-16 | 82 | 0d |  |  | Gustavo Ledezma; Yenny Colmenarez [50%] | 8h |
| 84 | 1.3.6.13 | Pantalla p/Analistas Despacho | 1d? | 2008-09-01 | 2008-09-01 |  | 75.92d |  |  |  | 4h |
| 85 | 1.3.7 | **Módulo de Apoyo al Cliente** | 24.5d? | 2008-10-20 | 2008-11-21 |  | 17.42d |  |  |  | 98h |
| 86 | 1.3.7.1 | Tablas Módulo Apoyo al Cliente | 0.5d? | 2008-10-20 | 2008-10-20 |  | 17.42d | 0d | start no earlier than 2008-10-20 | Jetzelis Heredia [50%] | 2h |
| 87 | 1.3.7.2 | Programas pre-post-formula | 2d? | 2008-10-20 | 2008-10-22 | 86 | 17.42d | 0d |  | Jetzelis Heredia [50%] | 8h |
| 88 | 1.3.7.3 | Ingreso de tickets | 2d? | 2008-10-22 | 2008-10-24 | 87 | 17.42d | 0d |  | Jetzelis Heredia [50%] | 8h |
| 89 | 1.3.7.4 | Cambio de estatus del ticket | 1d? | 2008-10-24 | 2008-10-27 | 88 | 17.42d | 0d |  | Jetzelis Heredia [50%] | 4h |
| 90 | 1.3.7.5 | Redireccionamiento de tickets | 2d? | 2008-10-27 | 2008-10-29 | 89 | 17.42d | 0d |  | Jetzelis Heredia [50%] | 8h |
| 91 | 1.3.7.6 | Reportes de tickets | 4d? | 2008-10-29 | 2008-11-04 | 90 | 17.42d | 0d |  | Jetzelis Heredia [50%] | 16h |
| 92 | 1.3.7.7 | Busquedas Apoyo al cliente | 2d? | 2008-11-04 | 2008-11-06 | 91 | 17.42d | 0d |  | Jetzelis Heredia [50%] | 8h |
| 93 | 1.3.7.8 | Reportes Apoyo al Cliente | 6d? | 2008-11-06 | 2008-11-14 | 92 | 17.42d | 0d |  | Jetzelis Heredia [50%] | 24h |
| 94 | 1.3.7.9 | Vistas extendidas Apoyo al Cliente | 4d? | 2008-11-14 | 2008-11-20 | 93 | 17.42d | 0d |  | Jetzelis Heredia [50%] | 16h |
| 95 | 1.3.7.10 | Pantalla p/Analistas Apoyo al cliente | 1d? | 2008-11-20 | 2008-11-21 | 94 | 17.42d |  |  | Jetzelis Heredia [50%] | 4h |

| ID | WBS | Task | Duration | Start | Finish | Predecessors | Total slack | Free slack | Resources | Work |
| --- | --- | --- | --- | --- | --- | --- | --- | --- | --- | --- |
| 96 | 1.3.8 | **General** | 4d? | 2008-09-09 | 2008-09-12 |  | 66.92d |  |  | 16h |
| 97 | 1.3.8.1 | Panel y Pantalla Principal | 2d? | 2008-09-09 | 2008-09-10 | 11 | 66.92d | 0d | Yenny Colmenarez [50%] | 8h |
| 98 | 1.3.8.2 | Administrador de niveles de acceso y usuarios | 2d? | 2008-09-11 | 2008-09-12 | 97 | 66.92d |  | Yenny Colmenarez [50%] | 8h |
| 99 | 1.4 | **Carga de datos** | 2d? | 2008-12-15 | 2008-12-17 |  | 0d |  |  | 44h |
| 100 | 1.4.1 | Programas de carga masiva de datos | 1d? | 2008-12-15 | 2008-12-16 | 12FS-1d | 0d |  |  | 24h |
| 101 | 1.4.2 | Carga Masiva y Revisión | 1d? | 2008-12-16 | 2008-12-17 | 100 | 0d |  |  | 20h |
| 102 | 1.5 | Pruebas | 1d? | 2008-12-12 | 2008-12-15 | 12FS-2d | 4d |  |  | 40h |
| 103 | 1.6 | Documentación | 1d? | 2008-12-16 | 2008-12-17 | 12 | 2d |  |  | 32h |
| 104 | 1.7 | Operacionalización | 1d? | 2008-12-17 | 2008-12-18 | 101 | 0d |  |  | 18h |
| 105 | 1.8 | Entrenamiento | 1d? | 2008-12-18 | 2008-12-19 | 104 | 0d |  |  | 18h |
| 106 | 1.9 | Gerencia Proyecto | 75d? | 2008-09-01 | 2008-12-12 |  | 4.92d |  | Marbella Colmenarez [25%] | 150h |
