# ttgoportunidades

Schedule from MS Project, 2005-11-23 to 2006-01-17, A marks actual dates.
GWT

## Calendars

- Estándar: Mon-Fri 09:00-13:00, 15:00-19:00; Sat-Sun off.

## Resources

| Resource |
| --- |
| V Riera |
| V R |
| H Rosas V Riera |
| O Lorenzo |
| O Lorenzo V Riera |
| Vriera |

## Schedule

| ID | WBS | Task | Duration | Start | Finish | Predecessors | Complete | Remaining | Baseline start | Baseline finish | Baseline duration | Total slack | Free slack | Constraint | Resources | Work | Actual work |
| --- | --- | --- | --- | --- | --- | --- | --- | --- | --- | --- | --- | --- | --- | --- | --- | --- | --- |
| 1 | 1 | **Gerencia oportunidades** | 40d? | 2005-11-23 A | 2006-01-17 |  | 34% | 26.37d? | 2005-11-23 | 2006-02-08 | 56d? | 0d |  |  |  | 436h | 152.72h |
| 3 | 1.1 | Inicio | 1d? | 2005-11-23 A | 2005-11-23 A |  | 100% |  | 2005-11-23 | 2005-11-23 | 1d? |  |  | start no earlier than 2005-11-23 |  |  |  |
| 4 | 1.2 | **Definición del proceso** | 18d? | 2005-11-29 A | 2005-12-22 |  | 82% | 3.24d? | 2005-11-23 | 2005-12-01 | 7d | 5d |  |  | V Riera | 188h | 152.72h |
| 5 | 1.2.1 | Establecimiento de procesos | 7d | 2005-11-29 A | 2005-12-13 A |  | 100% |  | 2005-12-02 | 2005-12-12 | 7d |  |  |  | V Riera | 56h | 56h |
| 6 | 1.2.2 | Establecimiento de procedimientos | 1d? | 2005-12-13 A | 2005-12-14 A | 5 | 100% |  |  |  |  |  |  |  |  |  |  |
| 7 | 1.2.3 | Propuesta de Métricas | 2d | 2005-12-21 A | 2005-12-22 |  | 10% | 1.8d | 2005-12-13 | 2005-12-21 | 7d | 5d | 0d | finish no earlier than 2005-12-22 | V Riera | 16h | 1.6h |
| 8 | 1.3 | **Incorporación a 701** | 18d? | 2005-12-23 | 2006-01-17 | 7 |  |  | 2006-01-16 | 2006-01-24 | 7d | 0d |  |  | H Rosas V Riera | 248h |  |
| 9 | 1.3.1 | Definición de Métricas | 1d? | 2006-01-12 | 2006-01-12 |  |  |  |  |  |  | 1d |  | start no earlier than 2006-01-12 |  |  |  |
| 10 | 1.3.2 | Definición de tablas | 1d? | 2006-01-16 | 2006-01-16 | 9 |  |  |  |  |  | 0d |  | start no earlier than 2006-01-16 | H Rosas V Riera | 8h |  |
| 11 | 1.3.3 | Definición de Campos | 1d? | 2006-01-17 | 2006-01-17 | 10 |  |  |  |  |  | 0d |  |  | H Rosas V Riera | 8h |  |
| 12 | 1.3.4 | Puesta en producción del sistema | 1d? | 2005-12-23 | 2005-12-23 |  |  |  |  |  |  | 5d | 0d |  |  |  |  |
| 13 | 1.3.5 | Prueba de Sistema | 10d | 2005-12-26 | 2006-01-06 | 12 |  |  | 2006-01-25 | 2006-02-07 | 10d | 5d | 0d |  | O Lorenzo V Riera | 80h |  |
| 14 | 1.3.6 | Aprobación del sistema | 1d? | 2006-01-09 | 2006-01-09 | 13 |  |  |  |  |  | 5d | 0d |  | V Riera | 8h |  |
| 15 | 1.4 | Cierre | 1d | 2006-01-10 | 2006-01-10 | 14 |  |  | 2006-02-08 | 2006-02-08 | 1d | 5d |  |  |  |  |  |
