# ArquinPostcardEstimation22112006

Schedule from MS Project, 2006-11-27 to 2006-12-06.
Globalwebtek Venezuela C.A.

## Calendars

- Standard: Mon-Fri 08:00-12:00, 13:00-17:00; Sat-Sun off.

## Resources

| Resource |
| --- |
| GWT |
| Tierra |

## Schedule

| ID | WBS | Task | Duration | Start | Finish | Predecessors | Total slack | Constraint | Resources | Work |
| --- | --- | --- | --- | --- | --- | --- | --- | --- | --- | --- |
| 1 | 1 | **Arquin Postcard Module** | 7.25d? | 2006-11-27 08:00 | 2006-12-06 10:00 |  | 0d |  |  | 64h |
| 2 | 1.1 | Moudle access without login | 0.25d | 2006-11-27 08:00 | 2006-11-27 10:00 |  | 0d | start no earlier than 2006-11-27 08:00 | GWT | 2h |
| 3 | 1.2 | Inclusion of the Arquin's banner in the product's home | 0.25d | 2006-11-27 10:00 | 2006-11-27 12:00 | 2 | 0d |  | GWT | 2h |
| 4 | 1.3 | Postcard home for the new partner | 0.5d | 2006-11-27 13:00 | 2006-11-27 17:00 | 3 | 0d |  | GWT | 4h |
| 5 | 1.4 | **Postcard's steps development** | 3.12d? | 2006-11-28 08:00 | 2006-12-01 09:00 |  | 0d |  |  | 25h |
| 6 | 1.4.1 | step 1: format choosing | 0.62d? | 2006-11-28 08:00 | 2006-11-28 14:00 | 4 | 0d |  | GWT | 5h |
| 7 | 1.4.2 | step 2: background choosing | 0.62d? | 2006-11-28 14:00 | 2006-11-29 10:00 | 6 | 0d |  | GWT | 5h |
| 8 | 1.4.3 | step 3: postcard front page construction | 0.62d? | 2006-11-29 10:00 | 2006-11-29 16:00 | 7 | 0d |  | GWT | 5h |
| 9 | 1.4.4 | step 3: back page construction and pdf preview | 0.62d? | 2006-11-29 16:00 | 2006-11-30 12:00 | 8 | 0d |  | GWT | 5h |
| 10 | 1.4.5 | step 4: finish of the process. Add the product to the shopping cart | 0.62d? | 2006-11-30 13:00 | 2006-12-01 09:00 | 9 | 0d |  | GWT | 5h |
| 11 | 1.5 | Prices configuration | 0.62d? | 2006-12-01 09:00 | 2006-12-01 15:00 | 10 | 0d |  | GWT | 5h |
| 12 | 1.6 | Internal Testing | 0.5d? | 2006-12-01 15:00 | 2006-12-04 10:00 | 11 | 0d |  | GWT | 4h |
| 13 | 1.7 | Formats and Themes incorporation (test material) | 1d? | 2006-12-04 10:00 | 2006-12-05 10:00 | 12 | 0d |  | Tierra | 8h |
| 14 | 1.8 | Certified Testing (Tierra) | 1d? | 2006-12-05 10:00 | 2006-12-06 10:00 | 13 | 0d |  | Tierra | 8h |
| 15 | 1.9 | Project Management | 0.74d? | 2006-11-29 10:04 | 2006-11-29 17:00 |  | 4.25d | finish no earlier than 2006-11-29 17:00 | GWT; Tierra | 6h |
