# Cronograma Base Datos Protocolar

Schedule from MS Project, 2008-04-07 to 2008-04-23.
gwt

## Calendars

- Estándar: Mon-Fri 09:00-13:00, 15:00-19:00; Sat-Sun off.

## Resources

| Resource |
| --- |
| Marbella Colmenarez |
| Analista Operaciones |
| Programador |

## Schedule

| ID | WBS | Task | Duration | Start | Finish | Predecessors | Total slack | Resources | Work |
| --- | --- | --- | --- | --- | --- | --- | --- | --- | --- |
| 1 | 1 | **Base de Datos Protocolar** | 12.75d? | 2008-04-07 | 2008-04-23 |  | 0d |  | 74h |
| 2 | 1.1 | Levantamiento de Información | 1d? | 2008-04-07 | 2008-04-07 |  | 0d | Marbella Colmenarez | 8h |
| 3 | 1.2 | Analisis | 2.75d? | 2008-04-08 | 2008-04-10 | 2 | 0d | Marbella Colmenarez | 22h |
| 4 | 1.3 | **Desarrollo** | 4d? | 2008-04-10 | 2008-04-16 |  | 0d |  | 28h |
| 5 | 1.3.1 | Creación de Tablas | 1d? | 2008-04-10 | 2008-04-11 | 3 | 0d | Programador [50%] | 4h |
| 6 | 1.3.2 | Reportes (5) | 2d? | 2008-04-11 | 2008-04-15 | 5 | 0d | Programador | 16h |
| 7 | 1.3.3 | Estadísticas (2) | 1d? | 2008-04-15 | 2008-04-16 | 6 | 0d | Programador | 8h |
| 8 | 1.4 | Pruebas | 1d? | 2008-04-16 | 2008-04-17 | 7 | 0d | Marbella Colmenarez [50%] | 4h |
| 9 | 1.5 | Documentación | 1d? | 2008-04-17 | 2008-04-18 | 8 | 0d | Programador [25%] | 2h |
| 10 | 1.6 | Operacionalizacion | 1d? | 2008-04-18 | 2008-04-21 | 9 | 0d | Analista Operaciones [50%] | 4h |
| 11 | 1.7 | Entrenamiento | 1d? | 2008-04-21 | 2008-04-22 | 10 | 0d | Marbella Colmenarez [25%] | 2h |
| 12 | 1.8 | Gerencia | 1d? | 2008-04-22 | 2008-04-23 | 11 | 0d | Marbella Colmenarez [50%] | 4h |
