# Sitio web para Cyngular

Schedule from MS Project, 2008-12-12 to 2009-07-23, A marks actual dates.
GWT

## Calendars

- Estándar: Mon-Fri 09:00-13:00, 15:00-19:00; Sat-Sun off. Exceptions (off unless hours are given): 2008-12-22 to 2009-01-13, 2009-01-14 09:00-13:00, 15:00-19:00, 2009-01-15, 2009-02-23 to 2009-02-24, 2009-04-09 to 2009-04-10, 2009-05-01, 2009-06-24.

## Resources

| Resource |
| --- |
| Diseñador |
| P1 |
| GP |
| OP |
| D1 |

## Schedule

| ID | WBS | Task | Type | Duration | Start | Finish | Predecessors | Complete | Remaining | Total slack | Constraint | Resources | Work | Actual work |
| --- | --- | --- | --- | --- | --- | --- | --- | --- | --- | --- | --- | --- | --- | --- |
| 1 | 1 | **Proyecto locosporloslibros.com** |  | 135.61d? | 2008-12-12 09:00 A | 2009-07-23 15:54 |  | 85% | 20.84d? | 0d |  |  | 723h | 554.75h |
| 2 | 1.1 | Análisis |  | 3d? | 2008-12-12 09:00 A | 2008-12-16 19:00 A |  | 100% |  |  | finish no earlier than 2008-12-16 19:00 |  | 20h | 20h |
| 3 | 1.2 | Modelaje de Datos |  | 3d? | 2009-02-05 09:00 A | 2009-02-09 19:00 A |  | 100% |  |  | start no earlier than 2009-02-05 09:00 | P1 [50%]; GP [50%] | 24h | 24h |
| 4 | 1.3 | Estructura del repositorio de datos del Site |  | 1d? | 2009-02-10 09:00 A | 2009-02-10 19:00 A | 3 | 100% |  |  |  | P1 | 8h | 8h |
| 5 | 1.4 | **Sitio Web** |  | 118.5d? | 2008-12-12 09:00 A | 2009-06-30 13:00 |  | 91% | 10.6d? | 17.11d |  |  | 372h | 328h |
| 6 | 1.4.1 | **Diseño Gráfico** |  | 54d? | 2008-12-12 09:00 A | 2009-03-25 19:00 A |  | 100% |  |  |  |  | 120h | 120h |
| 7 | 1.4.1.1 | Coordinación con diseñador gráfico |  | 23d? | 2008-12-12 09:00 A | 2009-02-06 19:00 A |  | 100% |  |  | start no earlier than 2008-12-12 09:00 |  |  |  |
| 8 | 1.4.1.2 | Recepción imágenes y manual de diseño | milestone | 0d | 2009-02-09 09:00 A | 2009-02-09 09:00 A | 7 | 100% |  |  | start no earlier than 2009-02-09 09:00 | P1 |  |  |
| 9 | 1.4.1.3 | Creación hojas de Estilo |  | 15d? | 2009-02-10 09:00 A | 2009-03-04 19:00 A | 8, 3 | 100% |  |  |  | D1 [50%] | 60h | 60h |
| 10 | 1.4.1.4 | Estructuración del sitio |  | 15d? | 2009-03-05 09:00 A | 2009-03-25 19:00 A | 9 | 100% |  |  |  | D1 [50%] | 60h | 60h |
| 11 | 1.4.2 | **Programación** |  | 87d? | 2009-02-19 15:00 A | 2009-06-30 13:00 |  | 84% | 14.19d? | 17.11d |  |  | 252h | 208h |
| 12 | 1.4.2.1 | **Secciones públicas** |  | 21d? | 2009-02-19 15:00 A | 2009-03-24 13:00 A |  | 100% |  |  |  |  | 120h | 120h |
| 13 | 1.4.2.1.1 | **Página principal** |  | 2d? | 2009-02-19 15:00 A | 2009-02-25 13:00 A |  | 100% |  |  |  |  | 16h | 16h |
| 14 | 1.4.2.1.1.1 | Enlaces de Interés |  | 0.25d? | 2009-02-19 15:00 A | 2009-02-19 17:00 A | 85 | 100% |  |  |  | P1 | 2h | 2h |
| 15 | 1.4.2.1.1.2 | Noticia Destacada |  | 0.25d? | 2009-02-19 17:00 A | 2009-02-19 19:00 A | 14 | 100% |  |  |  | P1 | 2h | 2h |
| 16 | 1.4.2.1.1.3 | Listado de Noticias recientes |  | 0.5d? | 2009-02-20 09:00 A | 2009-02-20 13:00 A | 15 | 100% |  |  |  | P1 | 4h | 4h |
| 17 | 1.4.2.1.1.4 | Autores |  | 0.25d? | 2009-02-20 15:00 A | 2009-02-20 17:00 A | 16 | 100% |  |  |  | P1 | 2h | 2h |
| 18 | 1.4.2.1.1.5 | Novedades |  | 0.25d? | 2009-02-20 17:00 A | 2009-02-20 19:00 A | 17 | 100% |  |  |  | P1 | 2h | 2h |
| 19 | 1.4.2.1.1.6 | El Librero |  | 0.25d? | 2009-02-25 09:00 A | 2009-02-25 11:00 A | 18 | 100% |  |  |  | P1 | 2h | 2h |
| 20 | 1.4.2.1.1.7 | Blogoteca |  | 0.25d? | 2009-02-25 11:00 A | 2009-02-25 13:00 A | 19 | 100% |  |  |  | P1 | 2h | 2h |
| 21 | 1.4.2.1.2 | **Novedades** |  | 4.5d? | 2009-02-25 15:00 A | 2009-03-03 19:00 A |  | 100% |  |  |  |  | 36h | 36h |
| 22 | 1.4.2.1.2.1 | Página de novedades |  | 1.5d? | 2009-02-25 15:00 A | 2009-02-26 19:00 A | 13 | 100% |  |  |  | P1 | 12h | 12h |
| 23 | 1.4.2.1.2.2 | Buscador de libros |  | 2d? | 2009-02-27 09:00 A | 2009-03-02 19:00 A | 22 | 100% |  |  |  | P1 | 16h | 16h |
| 24 | 1.4.2.1.2.3 | Detalle de Libro |  | 1d? | 2009-03-03 09:00 A | 2009-03-03 19:00 A | 23 | 100% |  |  |  | P1 | 8h | 8h |

| ID | WBS | Task | Duration | Start | Finish | Predecessors | Complete | Remaining | Total slack | Resources | Work | Actual work |
| --- | --- | --- | --- | --- | --- | --- | --- | --- | --- | --- | --- | --- |
| 25 | 1.4.2.1.3 | **Noticias** | 1.75d? | 2009-03-04 09:00 A | 2009-03-05 17:00 A |  | 100% |  |  |  | 14h | 14h |
| 26 | 1.4.2.1.3.1 | Página de Noticias | 1d? | 2009-03-04 09:00 A | 2009-03-04 19:00 A | 21 | 100% |  |  | P1 | 8h | 8h |
| 27 | 1.4.2.1.3.2 | Organización de Noticias por año y mes | 0.5d? | 2009-03-05 09:00 A | 2009-03-05 13:00 A | 26 | 100% |  |  | P1 | 4h | 4h |
| 28 | 1.4.2.1.3.3 | Detalle Noticia | 0.25d? | 2009-03-05 15:00 A | 2009-03-05 17:00 A | 27 | 100% |  |  | P1 | 2h | 2h |
| 29 | 1.4.2.1.4 | Blogoteca | 1d? | 2009-03-05 17:00 A | 2009-03-06 17:00 A | 25 | 100% |  |  | P1 | 8h | 8h |
| 30 | 1.4.2.1.5 | Contacto | 1.5d? | 2009-03-06 17:00 A | 2009-03-10 11:00 A | 29 | 100% |  |  | P1 | 12h | 12h |
| 31 | 1.4.2.1.6 | Despliegue de logos de Aliados | 0.5d? | 2009-03-10 11:00 A | 2009-03-10 17:00 A | 30 | 100% |  |  | P1 | 4h | 4h |
| 32 | 1.4.2.1.7 | Banners | 2.5d? | 2009-03-12 11:00 A | 2009-03-16 17:00 A | 86 | 100% |  |  | P1 | 20h | 20h |
| 33 | 1.4.2.1.8 | Pie de página | 0.25d? | 2009-03-17 11:00 A | 2009-03-17 13:00 A | 87 | 100% |  |  | P1 | 2h | 2h |
| 34 | 1.4.2.1.9 | Revisión por parte de Cyngular | 3d | 2009-03-17 15:00 A | 2009-03-20 13:00 A | 33 | 100% |  |  |  |  |  |
| 35 | 1.4.2.1.10 | Ajustes | 1d? | 2009-03-20 15:00 A | 2009-03-23 13:00 A | 34 | 100% |  |  | P1 | 8h | 8h |
| 36 | 1.4.2.1.11 | ENTREGA 1: SITIO WEB PÚBLICO en ambiente de desarrollo | 1d? | 2009-03-23 15:00 A | 2009-03-24 13:00 A | 35 | 100% |  |  |  |  |  |
| 37 | 1.4.2.2 | **Registro y secciones privadas** | 53.5d? | 2009-03-24 15:00 A | 2009-06-10 19:00 |  | 90% | 5.5d? | 29.61d |  | 96h | 88h |
| 38 | 1.4.2.2.1 | **Autenticación de usuario** | 2d? | 2009-03-24 15:00 A | 2009-03-26 13:00 A |  | 100% |  |  |  | 16h | 16h |
| 39 | 1.4.2.2.1.1 | Registro | 0.5d? | 2009-03-24 15:00 A | 2009-03-24 19:00 A | 12 | 100% |  |  | P1 | 4h | 4h |
| 40 | 1.4.2.2.1.2 | Ingreso de usuario | 0.5d? | 2009-03-25 09:00 A | 2009-03-25 13:00 A | 39 | 100% |  |  | P1 | 4h | 4h |
| 41 | 1.4.2.2.1.3 | Olvido de contraseña | 0.5d? | 2009-03-25 15:00 A | 2009-03-25 19:00 A | 40 | 100% |  |  | P1 | 4h | 4h |
| 42 | 1.4.2.2.1.4 | Detección de usuario autenticado | 0.5d? | 2009-03-26 09:00 A | 2009-03-26 13:00 A | 41 | 100% |  |  | P1 | 4h | 4h |
| 43 | 1.4.2.2.2 | **Autores** | 2d? | 2009-03-26 15:00 A | 2009-03-30 13:00 A |  | 100% |  |  |  | 16h | 16h |
| 44 | 1.4.2.2.2.1 | Listado de Autores | 1d? | 2009-03-26 15:00 A | 2009-03-27 13:00 A | 38 | 100% |  |  | P1 | 8h | 8h |
| 45 | 1.4.2.2.2.2 | Detalle de Autor | 1d? | 2009-03-27 15:00 A | 2009-03-30 13:00 A | 44 | 100% |  |  | P1 | 8h | 8h |
| 46 | 1.4.2.2.3 | **Eventos** | 1d? | 2009-03-30 15:00 A | 2009-03-31 13:00 A |  | 100% |  |  |  | 8h | 8h |
| 47 | 1.4.2.2.3.1 | Calendario Eventos | 0.5d? | 2009-03-30 15:00 A | 2009-03-30 19:00 A | 43 | 100% |  |  | P1 | 4h | 4h |
| 48 | 1.4.2.2.3.2 | Detalle Eventos | 0.5d? | 2009-03-31 09:00 A | 2009-03-31 13:00 A | 47 | 100% |  |  | P1 | 4h | 4h |

| ID | WBS | Task | Duration | Start | Finish | Predecessors | Complete | Remaining | Total slack | Free slack | Constraint | Resources | Work | Actual work |
| --- | --- | --- | --- | --- | --- | --- | --- | --- | --- | --- | --- | --- | --- | --- |
| 49 | 1.4.2.2.4 | **Novedades** | 1d? | 2009-04-02 15:00 A | 2009-04-03 13:00 A |  | 100% |  |  |  |  |  | 8h | 8h |
| 50 | 1.4.2.2.4.1 | Valoración para libros | 0.5d? | 2009-04-02 15:00 A | 2009-04-02 19:00 A |  | 100% |  |  |  |  | P1 | 4h | 4h |
| 51 | 1.4.2.2.4.2 | Comentarios para libros | 0.5d? | 2009-04-03 09:00 A | 2009-04-03 13:00 A | 50 | 100% |  |  |  |  | P1 | 4h | 4h |
| 52 | 1.4.2.2.5 | **El Librero** | 1.5d? | 2009-04-06 09:00 A | 2009-04-07 13:00 A |  | 100% |  |  |  |  |  | 12h | 12h |
| 53 | 1.4.2.2.5.1 | Edición reciente | 0.5d? | 2009-04-06 09:00 A | 2009-04-06 13:00 A |  | 100% |  |  |  |  | P1 | 4h | 4h |
| 54 | 1.4.2.2.5.2 | Ediciones anteriores | 1d? | 2009-04-06 15:00 A | 2009-04-07 13:00 A | 53 | 100% |  |  |  |  | P1 | 8h | 8h |
| 55 | 1.4.2.2.6 | Google analytics | 0.12d? | 2009-05-25 09:00 A | 2009-05-25 10:00 A |  | 100% |  |  |  |  | P1; GP | 2h | 2h |
| 56 | 1.4.2.2.7 | Ingreso de Contenido por parte de Cyngular | 20d | 2009-05-04 09:00 A | 2009-05-29 19:00 |  | 95% | 1d | 37.61d |  | finish no earlier than 2009-05-29 19:00 |  |  |  |
| 57 | 1.4.2.2.8 | Revisión por parte de Cyngular | 4d | 2009-05-26 09:00 A | 2009-05-29 19:00 A |  | 100% |  |  |  | finish no earlier than 2009-05-29 19:00 |  |  |  |
| 58 | 1.4.2.2.9 | Ajustes | 2d? | 2009-04-07 15:00 A | 2009-05-28 19:00 A | 52 | 100% |  |  |  |  | P1 [50%] | 8h | 8h |
| 59 | 1.4.2.2.10 | ENTREGA 2: SITIO WEB CON REGISTRO en ambiente de desarrollo | 1d? | 2009-05-29 09:00 | 2009-05-29 19:00 | 58 |  |  | 37.61d |  |  |  |  |  |
| 60 | 1.4.2.2.11 | Cambio Encabezado | 1d? | 2009-06-01 09:00 A | 2009-06-01 19:00 A | 59 | 100% |  |  |  |  | P1 | 8h | 8h |
| 61 | 1.4.2.2.12 | Cambio Banners | 0.5d? | 2009-06-02 09:00 A | 2009-06-02 13:00 A | 60 | 100% |  |  |  |  | P1 | 4h | 4h |
| 62 | 1.4.2.2.13 | **Boletines** | 0.75d? | 2009-06-02 15:00 A | 2009-06-03 11:00 A |  | 100% |  |  |  |  |  | 6h | 6h |
| 63 | 1.4.2.2.13.1 | Tabla de personas para envío de boletines | 0.25d? | 2009-06-02 15:00 A | 2009-06-02 17:00 A | 61 | 100% |  |  |  |  | P1 | 2h | 2h |
| 64 | 1.4.2.2.13.2 | Programa para marcar no recibir más boletines | 0.5d? | 2009-06-02 17:00 A | 2009-06-03 11:00 A | 63 | 100% |  |  |  |  | P1 | 4h | 4h |
| 65 | 1.4.2.2.14 | Puesta en producción Primera parte | 1d? | 2009-06-09 09:00 | 2009-06-09 19:00 |  |  |  | 0d |  | start no earlier than 2009-06-09 09:00 | OP | 8h |  |
| 66 | 1.4.2.2.15 | SITIO WEB PUBLICADO | 1d? | 2009-06-10 09:00 | 2009-06-10 19:00 | 65 |  |  | 0d |  |  |  |  |  |
| 67 | 1.4.2.3 | Recomendar blog al editor | 0.5d? | 2009-06-11 09:00 | 2009-06-11 13:00 | 66 |  |  | 0d |  |  | P1 | 4h |  |
| 68 | 1.4.2.4 | Proposición de noticia | 1d? | 2009-06-11 15:00 | 2009-06-12 13:00 | 67 |  |  | 0d |  |  | P1 | 8h |  |
| 69 | 1.4.2.5 | Proposición de evento | 1d? | 2009-06-12 15:00 | 2009-06-15 13:00 | 68 |  |  | 0d |  |  | P1 | 8h |  |
| 70 | 1.4.2.6 | **Suscripción** | 1d? | 2009-06-23 15:00 | 2009-06-25 13:00 |  |  |  | 0d |  |  |  | 8h |  |
| 71 | 1.4.2.6.1 | Formulario de suscripción | 0.5d? | 2009-06-23 15:00 | 2009-06-23 19:00 | 89 |  |  | 0d |  |  | P1 | 4h |  |
| 72 | 1.4.2.6.2 | Formulario para registro de pago | 0.5d? | 2009-06-25 09:00 | 2009-06-25 13:00 | 71 |  |  | 0d |  |  | P1 | 4h |  |
| 73 | 1.4.2.7 | Revisión por parte de Cyngular | 1d | 2009-06-25 15:00 | 2009-06-26 13:00 | 70 |  |  | 17.11d | 0d |  |  |  |  |
| 74 | 1.4.2.8 | Ajustes | 1d? | 2009-06-26 15:00 | 2009-06-29 13:00 | 73 |  |  | 17.11d | 0d |  | P1 | 8h |  |
| 75 | 1.4.2.9 | ENTREGA 3: SITIO WEB COMPLETO en ambiente de desarrollo | 1d? | 2009-06-29 15:00 | 2009-06-30 13:00 | 74 |  |  | 17.11d |  |  |  |  |  |

| ID | WBS | Task | Duration | Start | Finish | Predecessors | Complete | Remaining | Total slack | Resources | Work | Actual work |
| --- | --- | --- | --- | --- | --- | --- | --- | --- | --- | --- | --- | --- |
| 76 | 1.5 | **Backoffice** | 97.05d? | 2009-02-11 09:00 A | 2009-07-06 09:24 |  | 47% | 51.01d? | 0d |  | 139h | 88.2h |
| 77 | 1.5.1 | Manejo de Enlaces de interés | 0.25d? | 2009-02-11 09:00 A | 2009-02-11 11:00 A | 4 | 100% |  |  | P1 | 2h | 2h |
| 78 | 1.5.2 | Manejo de Noticias | 0.5d? | 2009-02-11 11:00 A | 2009-02-11 17:00 A | 77 | 100% |  |  | P1 | 4h | 4h |
| 79 | 1.5.3 | Manejo de Autores | 0.5d? | 2009-02-11 17:00 A | 2009-02-12 11:00 A | 78 | 100% |  |  | P1 | 4h | 4h |
| 80 | 1.5.4 | Manejo de Eventos | 1d? | 2009-02-12 11:00 A | 2009-02-13 11:00 A | 79 | 100% |  |  | P1 | 8h | 8h |
| 81 | 1.5.5 | Manejo de Libros | 1d? | 2009-02-13 11:00 A | 2009-02-16 11:00 A | 80 | 100% |  |  | P1 | 8h | 8h |
| 82 | 1.5.6 | Manejo de Números de El Librero | 1d? | 2009-02-16 11:00 A | 2009-02-17 11:00 A | 81 | 100% |  |  | P1 | 8h | 8h |
| 83 | 1.5.7 | Manejo de Blogs | 1d? | 2009-02-17 11:00 A | 2009-02-18 11:00 A | 82 | 100% |  |  | P1 | 8h | 8h |
| 84 | 1.5.8 | Manejo de Contactos | 1d? | 2009-02-18 11:00 A | 2009-02-19 11:00 A | 83 | 100% |  |  | P1 | 8h | 8h |
| 85 | 1.5.9 | Manejo de Aliados | 0.25d? | 2009-02-19 11:00 A | 2009-02-19 13:00 A | 84 | 100% |  |  | P1 | 2h | 2h |
| 86 | 1.5.10 | Administración de banners | 1.5d? | 2009-03-10 17:00 A | 2009-03-12 11:00 A | 31 | 100% |  |  | P1 | 12h | 12h |
| 87 | 1.5.11 | Contenido Pie de página | 0.5d? | 2009-03-16 17:00 A | 2009-03-17 11:00 A | 32 | 100% |  |  | P1 | 4h | 4h |
| 88 | 1.5.12 | Manejo de Usuarios registrados | 0.12d? | 2009-04-07 15:00 A | 2009-04-07 16:00 A | 54 | 100% |  |  | P1 | 1h | 1h |
| 89 | 1.5.13 | Módulo de manejo de contenido publicado por usuarios | 6d? | 2009-06-15 15:00 | 2009-06-23 13:00 | 69 |  |  | 0d | P1 [50%] | 24h |  |
| 90 | 1.5.14 | Manejo de Suscripciones | 3d? | 2009-04-20 15:00 A | 2009-06-29 18:12 | 70 | 20% | 2.4d? | 0d | P1 [50%] | 12h | 2.4h |
| 91 | 1.5.15 | Manejo de Pagos pendientes y aprobación de pagos | 4d? | 2009-06-29 18:12 | 2009-07-03 18:12 | 90 |  |  | 0d | P1 [50%] | 16h |  |
| 92 | 1.5.16 | Reportes básicos por tabla | 1.5d? | 2009-04-29 15:00 A | 2009-07-06 09:24 | 91 | 90% | 0.15d? | 0d | P1 | 12h | 10.8h |
| 93 | 1.5.17 | Administración de usuarios Backoffice | 0.25d? | 2009-05-04 09:00 A | 2009-05-04 11:00 A | 92 | 100% |  |  | P1 | 2h | 2h |
| 94 | 1.5.18 | Configuración de perfiles de usuarios del Backoffice | 0.5d? | 2009-05-04 11:00 A | 2009-05-04 17:00 A | 93 | 100% |  |  | P1 | 4h | 4h |
| 95 | 1.6 | Pruebas internas y ajustes | 2d? | 2009-07-06 09:24 | 2009-07-08 09:24 | 76 |  |  | 0d | P1 | 16h |  |
| 96 | 1.7 | Guia de Usuario | 3d? | 2009-07-08 09:24 | 2009-07-13 09:24 | 95 |  |  | 0d | P1 | 24h |  |
| 97 | 1.8 | Adiestramiento Usuario Backoffice | 0.25d? | 2009-05-11 17:00 A | 2009-07-13 10:24 | 96 | 50% | 0.12d? | 0d | P1; GP | 4h | 2h |
| 98 | 1.9 | Adiestramiento Administrador Backoffice | 0.12d? | 2009-07-07 10:48 A | 2009-07-13 10:54 | 97 | 50% | 0.06d? | 0d | P1; GP | 2h | 1h |
| 99 | 1.10 | Pruebas de Certificación de Cyngular | 5d | 2009-07-13 10:54 | 2009-07-20 10:54 | 98 |  |  | 0d |  |  |  |
| 100 | 1.11 | Ajustes | 2d? | 2009-07-20 10:54 | 2009-07-22 10:54 | 99 |  |  | 0d | P1 | 16h |  |
| 101 | 1.12 | Puesta en producción Interacción usuario y Suscripción | 1d? | 2009-07-22 10:54 | 2009-07-23 10:54 | 100 |  |  | 0d | OP | 8h |  |

| ID | WBS | Task | Duration | Start | Finish | Predecessors | Complete | Remaining | Total slack | Constraint | Resources | Work | Actual work |
| --- | --- | --- | --- | --- | --- | --- | --- | --- | --- | --- | --- | --- | --- |
| 102 | 1.13 | **Gerencia de proyectos** | 133.61d? | 2008-12-16 09:00 A | 2009-07-23 15:54 |  | 96% | 5.99d? | 0d |  |  | 90h | 83.55h |
| 103 | 1.13.1 | Planificación | 0.5d? | 2008-12-16 09:00 A | 2008-12-16 13:00 A |  | 100% |  |  |  | GP | 4h | 4h |
| 104 | 1.13.2 | Control y Seguimiento | 86.25d? | 2009-01-14 09:00 A | 2009-05-22 11:00 |  | 95% | 4.31d? | 43.36d | start no earlier than 2009-01-14 09:00 | GP [10%] | 69h | 65.55h |
| 105 | 1.13.3 | Levantamiento de Información | 17.5d? | 2009-01-23 09:00 A | 2009-02-17 13:00 A |  | 100% |  |  | start no earlier than 2009-01-14 09:00 | GP [10%] | 14h | 14h |
| 106 | 1.13.4 | Cierre (Acta y Reunión) | 0.38d? | 2009-07-23 10:54 | 2009-07-23 15:54 | 101 |  |  | 0d |  | GP | 3h |  |
