# Sitio web para Cyngular

Schedule from MS Project, 2009-07-20 to 2009-11-05, status date 2009-07-14.
GWT

## Calendars

- Estándar: Mon-Fri 09:00-13:00, 15:00-19:00; Sat-Sun off.

## Resources

| Resource |
| --- |
| Diseñador |
| Programador |
| Analista |
| Operación |
| Gerente Proyecto |

## Schedule

| ID | WBS | Task | Type | Duration | Start | Finish | Predecessors | Total slack | Resources | Work |
| --- | --- | --- | --- | --- | --- | --- | --- | --- | --- | --- |
| 1 | 1 | **Proyecto E-Business Anatel** |  | 78.25d? | 2009-07-20 09:00 | 2009-11-05 11:00 |  | 0d |  | 554.5h |
| 2 | 1.1 | Crear Ambiente de Desarrollo |  | 8h | 2009-07-20 09:00 | 2009-07-20 19:00 |  | 0d | Operación | 8h |
| 3 | 1.2 | **Análisis Especificaciones** |  | 11d | 2009-07-21 09:00 | 2009-08-04 19:00 | 2 | 0d |  | 88h |
| 4 | 1.2.1 | Levantar Información (Sitio Web, Interfaz) |  | 24h | 2009-07-21 09:00 | 2009-07-23 19:00 |  | 0d | Analista | 24h |
| 5 | 1.2.2 | Analsis de Información |  | 16h | 2009-07-24 09:00 | 2009-07-27 19:00 | 4 | 0d | Analista | 16h |
| 6 | 1.2.3 | Documentación |  | 8h | 2009-07-28 09:00 | 2009-07-28 19:00 | 5 | 0d | Analista | 8h |
| 7 | 1.2.4 | Revisión del Cliente |  | 8h | 2009-07-29 09:00 | 2009-07-29 19:00 | 6 | 0d |  | 8h |
| 8 | 1.2.5 | Ajustes al Informe |  | 8h | 2009-07-30 09:00 | 2009-07-30 19:00 | 7 | 0d | Analista | 8h |
| 9 | 1.2.6 | Aprobación del Cliente |  | 8h | 2009-07-31 09:00 | 2009-07-31 19:00 | 8 | 0d |  | 8h |
| 10 | 1.2.7 | Modelaje de Datos |  | 8h | 2009-08-03 09:00 | 2009-08-03 19:00 | 9 | 0d | Analista | 8h |
| 11 | 1.2.8 | Estructura del repositorio de datos del Site |  | 8h | 2009-08-04 09:00 | 2009-08-04 19:00 | 10 | 0d | Analista | 8h |
| 12 | 1.3 | **Sitio Web** |  | 52.75d? | 2009-08-05 09:00 | 2009-10-16 17:00 | 3 | 0d |  | 350.5h |
| 13 | 1.3.1 | **Diseño Gráfico** |  | 9d | 2009-08-05 09:00 | 2009-08-17 19:00 |  | 0d |  | 24h |
| 14 | 1.3.1.1 | Diseño del Feel |  | 16h | 2009-08-05 09:00 | 2009-08-06 19:00 |  | 0d | Diseñador [50%] | 8h |
| 15 | 1.3.1.2 | Revisión y Aprobación del Cliente |  | 8h | 2009-08-07 09:00 | 2009-08-07 19:00 | 14 | 0d |  |  |
| 16 | 1.3.1.3 | Diseño del Look |  | 24h | 2009-08-10 09:00 | 2009-08-12 19:00 | 15 | 0d | Diseñador [50%] | 12h |
| 17 | 1.3.1.4 | Revisión y Aprobación del Cliente |  | 8h | 2009-08-13 09:00 | 2009-08-13 19:00 | 16 | 0d |  |  |
| 18 | 1.3.1.5 | Creación hojas de Estilo |  | 8h | 2009-08-14 09:00 | 2009-08-14 19:00 | 17 | 0d | Diseñador [25%] | 2h |
| 19 | 1.3.1.6 | Estructuración del sitio |  | 8h | 2009-08-17 09:00 | 2009-08-17 19:00 | 18 | 0d | Diseñador [25%] | 2h |
| 20 | 1.3.1.7 | Revisión y Aprobación del Cliente | milestone | 0h | 2009-08-17 19:00 | 2009-08-17 19:00 | 19 | 0d |  |  |
| 21 | 1.3.2 | **Secciones públicas** |  | 19.25d | 2009-08-18 09:00 | 2009-09-14 11:00 | 13 | 0d |  | 142.5h |
| 22 | 1.3.2.1 | **Página principal** |  | 3.5d | 2009-08-18 09:00 | 2009-08-21 13:00 |  | 0d |  | 28h |
| 23 | 1.3.2.1.1 | Mensaje Contenido |  | 4h | 2009-08-18 09:00 | 2009-08-18 13:00 |  | 0d | Programador | 4h |
| 24 | 1.3.2.1.2 | Noticias Destacadas |  | 2h | 2009-08-18 15:00 | 2009-08-18 17:00 | 23 | 0d | Programador | 2h |
| 25 | 1.3.2.1.3 | Invitación |  | 4h | 2009-08-18 17:00 | 2009-08-19 11:00 | 24 | 0d | Programador | 4h |
| 26 | 1.3.2.1.4 | Selección de País |  | 2h | 2009-08-19 11:00 | 2009-08-19 13:00 | 25 | 0d | Programador | 2h |
| 27 | 1.3.2.1.5 | Header |  | 8h | 2009-08-19 15:00 | 2009-08-20 13:00 | 26 | 0d | Programador | 8h |
| 28 | 1.3.2.1.6 | Footer |  | 8h | 2009-08-20 15:00 | 2009-08-21 13:00 | 27 | 0d | Programador | 8h |

| ID | WBS | Task | Type | Duration | Start | Finish | Predecessors | Total slack | Resources | Work |
| --- | --- | --- | --- | --- | --- | --- | --- | --- | --- | --- |
| 29 | 1.3.2.2 | **Pagina Paìs** |  | 2.75d | 2009-08-21 15:00 | 2009-08-26 11:00 | 22 | 0d |  | 16.5h |
| 30 | 1.3.2.2.1 | Mensaje de Contenido |  | 4h | 2009-08-21 15:00 | 2009-08-21 19:00 |  | 0d | Programador | 4h |
| 31 | 1.3.2.2.2 | Invitación |  | 4h | 2009-08-24 09:00 | 2009-08-24 13:00 | 30 | 0d | Programador | 4h |
| 32 | 1.3.2.2.3 | Video |  | 4h | 2009-08-24 15:00 | 2009-08-24 19:00 | 31 | 0d | Programador | 4h |
| 33 | 1.3.2.2.4 | Banners |  | 4h | 2009-08-25 09:00 | 2009-08-25 13:00 | 32 | 0d | Programador [50%] | 2h |
| 34 | 1.3.2.2.5 | Busqueda |  | 4h | 2009-08-25 15:00 | 2009-08-25 19:00 | 33 | 0d | Programador [50%] | 2h |
| 35 | 1.3.2.2.6 | Menu Navegación |  | 2h | 2009-08-26 09:00 | 2009-08-26 11:00 | 34 | 0d | Programador [25%] | 0.5h |
| 36 | 1.3.2.3 | **Menú de Navegación** |  | 12d | 2009-08-26 11:00 | 2009-09-11 11:00 | 29 | 0d |  | 90h |
| 37 | 1.3.2.3.1 | Inicio |  | 2h | 2009-08-26 11:00 | 2009-08-26 13:00 |  | 0d | Programador | 2h |
| 38 | 1.3.2.3.2 | Quienes Somos |  | 4h | 2009-08-26 15:00 | 2009-08-26 19:00 | 37 | 0d | Programador | 4h |
| 39 | 1.3.2.3.3 | Productos |  | 8h | 2009-08-27 09:00 | 2009-08-27 19:00 | 38 | 0d | Programador | 8h |
| 40 | 1.3.2.3.4 | Ofertas |  | 8h | 2009-08-28 09:00 | 2009-08-28 19:00 | 39 | 0d | Programador | 8h |
| 41 | 1.3.2.3.5 | Carrito de Compra |  | 12h | 2009-08-31 09:00 | 2009-09-01 13:00 | 40 | 0d | Programador | 12h |
| 42 | 1.3.2.3.6 | Mis Datos |  | 4h | 2009-09-01 15:00 | 2009-09-01 19:00 | 41 | 0d | Programador | 4h |
| 43 | 1.3.2.3.7 | Mi Cuenta |  | 4h | 2009-09-02 09:00 | 2009-09-02 13:00 | 42 | 0d | Programador | 4h |
| 44 | 1.3.2.3.8 | Preguntas Frecuentes |  | 4h | 2009-09-02 15:00 | 2009-09-02 19:00 | 43 | 0d | Programador [50%] | 2h |
| 45 | 1.3.2.3.9 | Nuestras Tiendas |  | 4h | 2009-09-03 09:00 | 2009-09-03 13:00 | 44 | 0d | Programador [50%] | 2h |
| 46 | 1.3.2.3.10 | Contactenos |  | 2h | 2009-09-03 15:00 | 2009-09-03 17:00 | 45 | 0d | Programador | 2h |
| 47 | 1.3.2.3.11 | Busqueda rápida de Productos |  | 4h | 2009-09-03 17:00 | 2009-09-04 11:00 | 46 | 0d | Programador [50%] | 2h |
| 48 | 1.3.2.3.12 | Mostrar Productos con Foto y Precio/Oferta |  | 8h | 2009-09-04 11:00 | 2009-09-07 11:00 | 47 | 0d | Programador | 8h |
| 49 | 1.3.2.3.13 | Productos Alternos |  | 8h | 2009-09-07 11:00 | 2009-09-08 11:00 | 48 | 0d | Programador | 8h |
| 50 | 1.3.2.3.14 | Hacer una Compra |  | 24h | 2009-09-08 11:00 | 2009-09-11 11:00 | 49 | 0d | Programador | 24h |
| 51 | 1.3.2.4 | Revisión del Cliente | milestone | 0h | 2009-09-11 11:00 | 2009-09-11 11:00 | 50 | 0d |  |  |
| 52 | 1.3.2.5 | Ajustes Sección Pública |  | 8h | 2009-09-11 11:00 | 2009-09-14 11:00 | 51 | 0d | Programador | 8h |
| 53 | 1.3.2.6 | ENTREGA 1: SITIO WEB PÚBLICO en ambiente de desarrollo | milestone | 0h | 2009-09-14 11:00 | 2009-09-14 11:00 | 52 | 0d |  |  |

| ID | WBS | Task | Type | Duration | Start | Finish | Predecessors | Total slack | Resources | Work |
| --- | --- | --- | --- | --- | --- | --- | --- | --- | --- | --- |
| 54 | 1.3.3 | **Secciones Privadas** |  | 10d? | 2009-09-14 11:00 | 2009-09-28 11:00 | 21 | 0d |  | 68h |
| 55 | 1.3.3.1 | Autenticación de usuario |  | 1d? | 2009-09-14 11:00 | 2009-09-15 11:00 |  | 0d |  | 16h |
| 56 | 1.3.3.2 | Mis Datos |  | 1d? | 2009-09-15 11:00 | 2009-09-16 11:00 | 55 | 0d |  | 8h |
| 57 | 1.3.3.3 | Mi Cuenta |  | 1d? | 2009-09-16 11:00 | 2009-09-17 11:00 | 56 | 0d |  | 4h |
| 58 | 1.3.3.4 | Boton de Pago Venezuela |  | 1d? | 2009-09-17 11:00 | 2009-09-18 11:00 | 57 | 0d |  | 32h |
| 59 | 1.3.3.5 | Revisión del Cliente |  | 3d | 2009-09-18 11:00 | 2009-09-23 11:00 | 58 | 0d |  |  |
| 60 | 1.3.3.6 | Ajustes Secciones Privadas |  | 2d? | 2009-09-23 11:00 | 2009-09-25 11:00 | 59 | 0d | Programador [50%] | 8h |
| 61 | 1.3.3.7 | ENTREGA 2: SITIO WEB Privado en ambiente de desarrollo |  | 1d? | 2009-09-25 11:00 | 2009-09-28 11:00 | 60 | 0d |  |  |
| 62 | 1.3.4 | **BackOffice** |  | 14.5d | 2009-09-28 11:00 | 2009-10-16 17:00 | 54 | 0d |  | 116h |
| 63 | 1.3.4.1 | Manejo de Enlaces de interés |  | 2h | 2009-09-28 11:00 | 2009-09-28 13:00 |  | 0d | Programador | 2h |
| 64 | 1.3.4.2 | Manejo de Noticias |  | 4h | 2009-09-28 15:00 | 2009-09-28 19:00 | 63 | 0d | Programador | 4h |
| 65 | 1.3.4.3 | Manejo de Quienes Somos |  | 4h | 2009-09-29 09:00 | 2009-09-29 13:00 | 64 | 0d | Programador | 4h |
| 66 | 1.3.4.4 | Manejo de Productos |  | 8h | 2009-09-29 15:00 | 2009-09-30 13:00 | 65 | 0d | Programador | 8h |
| 67 | 1.3.4.5 | Manejo de Ofertas |  | 4h | 2009-09-30 15:00 | 2009-09-30 19:00 | 66 | 0d | Programador | 4h |
| 68 | 1.3.4.6 | Manejo de Mis Datos |  | 4h | 2009-10-01 09:00 | 2009-10-01 13:00 | 67 | 0d | Programador | 4h |
| 69 | 1.3.4.7 | Manejo de Administración de Usuarios |  | 4h | 2009-10-01 15:00 | 2009-10-01 19:00 | 68 | 0d | Programador | 4h |
| 70 | 1.3.4.8 | Manejo de Mi Cuenta |  | 4h | 2009-10-02 09:00 | 2009-10-02 13:00 | 69 | 0d | Programador | 4h |
| 71 | 1.3.4.9 | Manejo de Nuestras Tiendas |  | 2h | 2009-10-02 15:00 | 2009-10-02 17:00 | 70 | 0d | Programador | 2h |
| 72 | 1.3.4.10 | Manejo de Preguntas Frecuentes |  | 2h | 2009-10-02 17:00 | 2009-10-02 19:00 | 71 | 0d | Programador | 2h |
| 73 | 1.3.4.11 | Administración de banners |  | 4h | 2009-10-05 09:00 | 2009-10-05 13:00 | 72 | 0d | Programador | 4h |
| 74 | 1.3.4.12 | Contenido Pie de página |  | 4h | 2009-10-05 15:00 | 2009-10-05 19:00 | 73 | 0d | Programador | 4h |
| 75 | 1.3.4.13 | Manejo de Usuarios registrados |  | 2h | 2009-10-06 09:00 | 2009-10-06 11:00 | 74 | 0d | Programador | 2h |
| 76 | 1.3.4.14 | Manejo de Pagos pendientes y aprobación de pagos |  | 16h | 2009-10-06 11:00 | 2009-10-08 11:00 | 75 | 0d | Programador | 16h |
| 77 | 1.3.4.15 | Reportes básicos por tabla |  | 16h | 2009-10-08 11:00 | 2009-10-12 11:00 | 76 | 0d | Programador | 16h |
| 78 | 1.3.4.16 | Administración de usuarios Backoffice |  | 2h | 2009-10-12 11:00 | 2009-10-12 13:00 | 77 | 0d | Programador | 2h |
| 79 | 1.3.4.17 | Adminstración de Clientes y Descuentos |  | 2h | 2009-10-12 15:00 | 2009-10-12 17:00 | 78 | 0d | Programador | 2h |
| 80 | 1.3.4.18 | Administración de Disponibilidad y Precios |  | 4h | 2009-10-12 17:00 | 2009-10-13 11:00 | 79 | 0d | Programador | 4h |
| 81 | 1.3.4.19 | Administración de Soliciitud de Pedidio |  | 4h | 2009-10-13 11:00 | 2009-10-13 17:00 | 80 | 0d | Programador | 4h |
| 82 | 1.3.4.20 | Configuración de perfiles de usuarios del Backoffice |  | 4h | 2009-10-13 17:00 | 2009-10-14 11:00 | 81 | 0d | Programador | 4h |
| 83 | 1.3.4.21 | Administración de Pagos |  | 8h | 2009-10-14 11:00 | 2009-10-15 11:00 | 82 | 0d | Programador | 8h |
| 84 | 1.3.4.22 | Manejo de Interacciones |  | 4h | 2009-10-15 11:00 | 2009-10-15 17:00 | 83 | 0d | Programador | 4h |
| 85 | 1.3.4.23 | Administración de Contactenos |  | 4h | 2009-10-15 17:00 | 2009-10-16 11:00 | 84 | 0d | Programador | 4h |
| 86 | 1.3.4.24 | Revisión del Cliente | milestone | 0h | 2009-10-16 11:00 | 2009-10-16 11:00 | 85 | 0d |  |  |
| 87 | 1.3.4.25 | Ajuste BackOffice |  | 4h | 2009-10-16 11:00 | 2009-10-16 17:00 | 86 | 0d | Programador | 4h |
| 88 | 1.3.4.26 | ENTREGA 3:Sitio Web Backoffice | milestone | 0h | 2009-10-16 17:00 | 2009-10-16 17:00 | 87 | 0d |  |  |

| ID | WBS | Task | Type | Duration | Start | Finish | Predecessors | Total slack | Resources | Work |
| --- | --- | --- | --- | --- | --- | --- | --- | --- | --- | --- |
| 89 | 1.4 | **Interfaz** |  | 8d | 2009-10-16 17:00 | 2009-10-28 17:00 | 62 | 0d |  | 64h |
| 90 | 1.4.1 | Carga de Productos |  | 8h | 2009-10-16 17:00 | 2009-10-19 17:00 |  | 0d |  | 8h |
| 91 | 1.4.2 | Saint Venezuela |  | 24h | 2009-10-19 17:00 | 2009-10-22 17:00 | 90 | 0d | Programador | 24h |
| 92 | 1.4.3 | Saint Colombia |  | 16h | 2009-10-22 17:00 | 2009-10-26 17:00 | 91 | 0d | Programador | 16h |
| 93 | 1.4.4 | Revisión del Cliente |  | 8h | 2009-10-26 17:00 | 2009-10-27 17:00 | 92 | 0d |  | 8h |
| 94 | 1.4.5 | Ajustes Interfaz |  | 8h | 2009-10-27 17:00 | 2009-10-28 17:00 | 93 | 0d | Programador | 8h |
| 95 | 1.4.6 | ENTREGA 4: Interfaz en ambiente de desarrollo | milestone | 0h | 2009-10-28 17:00 | 2009-10-28 17:00 | 94 | 0d |  |  |
| 96 | 1.5 | **Adiestramiemnto** |  | 1.5d | 2009-10-28 17:00 | 2009-10-30 11:00 |  | 0d |  | 12h |
| 97 | 1.5.1 | Guia de Usuario |  | 6h | 2009-10-28 17:00 | 2009-10-29 13:00 | 89 | 0d | Analista | 6h |
| 98 | 1.5.2 | Adiestramiento Usuario Backoffice |  | 4h | 2009-10-29 15:00 | 2009-10-29 19:00 | 97 | 0d | Analista | 4h |
| 99 | 1.5.3 | Adiestramiento Administrador Backoffice |  | 2h | 2009-10-30 09:00 | 2009-10-30 11:00 | 98 | 0d | Analista | 2h |
| 100 | 1.6 | **Certificacion y Carga** |  | 2d | 2009-10-30 11:00 | 2009-11-03 11:00 |  | 0d |  | 16h |
| 101 | 1.6.1 | Pruebas de Certificación Cliente | milestone | 0h | 2009-10-30 11:00 | 2009-10-30 11:00 | 99 | 0d |  |  |
| 102 | 1.6.2 | Ingreso de Contenido | milestone | 0h | 2009-10-30 11:00 | 2009-10-30 11:00 | 101 | 0d |  |  |
| 103 | 1.6.3 | Ajustes Finales |  | 16h | 2009-10-30 11:00 | 2009-11-03 11:00 | 102 | 0d | Programador | 16h |
| 104 | 1.7 | **Producción** |  | 1.75d | 2009-11-03 11:00 | 2009-11-04 19:00 |  | 0d |  | 14h |
| 105 | 1.7.1 | Crear Ambiente de Producción |  | 8h | 2009-11-03 11:00 | 2009-11-04 11:00 | 103 | 0d | Operación | 8h |
| 106 | 1.7.2 | Migrar Ambiente de Desarrollo a Producción |  | 4h | 2009-11-04 11:00 | 2009-11-04 17:00 | 105 | 0d | Operación | 4h |
| 107 | 1.7.3 | Google Analytics |  | 2h | 2009-11-04 17:00 | 2009-11-04 19:00 | 106 | 0d | Programador | 2h |
| 108 | 1.8 | Gerencia de proyectos | milestone | 0h | 2009-07-20 09:00 | 2009-07-20 09:00 |  | 78d | Gerente Proyecto [10%] |  |
| 109 | 1.9 | Cierre de Proyecto | milestone | 2h | 2009-11-05 09:00 | 2009-11-05 11:00 | 108, 104 | 0d | Gerente Proyecto | 2h |
